# SureScripts Partner Implementation 110804

How a schedule from MS Project changed from version to version. A marks actual dates.

## Version 1 (saved 2005-02-28, file Partner Implementation Plan - DateUpdated.mpp)

| ID | WBS | Task | Duration | Start | Finish | Predecessors | Total float |
| --- | --- | --- | --- | --- | --- | --- | --- |
| 1 | 1 | **SureScripts Implementation Project** | 116d | 2004-11-01 | 2005-04-11 |  | 0d |
| 2 | 1.1 | **Initiation Phase** | 15d | 2004-11-01 | 2004-11-19 |  | 0d |
| 3 |  | NDA executed | 5d | 2004-11-01 | 2004-11-05 |  | 0d |
| 4 |  | Deliver implementation documentation | 1d | 2004-11-08 | 2004-11-08 | 3 | 0d |
| 5 |  | Contract ratified | 0d | 2004-11-08 | 2004-11-08 | 4 | 0d |
| 6 | 1.1.4 | **Project Planning** | 9d | 2004-11-09 | 2004-11-19 | 5 | 0d |
| 7 |  | Revise implementation template | 5d | 2004-11-09 | 2004-11-15 |  | 0d |
| 8 |  | Distribute for comment | 1d | 2004-11-16 | 2004-11-16 | 7 | 0d |
| 9 |  | Review/modify plan | 3d | 2004-11-17 | 2004-11-19 | 8 | 0d |
| 10 |  | Implementation plan complete | 0d | 2004-11-19 | 2004-11-19 | 9 | 0d |
| 11 | 1.2 | **Requirements & Analysis Phase** | 24d | 2004-11-22 | 2004-12-23 | 10 | 0d |
| 12 |  | Initial implementation call | 1d | 2004-11-22 | 2004-11-22 |  | 99d |
| 13 | 1.2.2 | **Connectivity Requirements** | 8d | 2004-11-22 | 2004-12-01 |  | 16d |
| 14 |  | Define environments | 3d | 2004-11-22 | 2004-11-24 |  | 98d |
| 15 |  | Assess aggregator requirements | 3d | 2004-11-22 | 2004-11-24 |  | 98d |
| 16 |  | Assess connectivity mgmt | 3d | 2004-11-22 | 2004-11-24 |  | 98d |
| 17 |  | Assess DNS requirements | 3d | 2004-11-22 | 2004-11-24 |  | 98d |
| 18 |  | Assess throughput requirements | 3d | 2004-11-22 | 2004-11-24 |  | 16d |
| 19 |  | Assess environment requirements/impact | 2d | 2004-11-25 | 2004-11-26 | 18 | 16d |
| 20 |  | Update solution document w/requirements & assumptions | 2d | 2004-11-29 | 2004-11-30 | 19 | 16d |
| 21 |  | Conduct connectivity risk analysis | 1d | 2004-12-01 | 2004-12-01 | 20 | 16d |
| 22 |  | Connectivity requirements complete | 0d | 2004-12-01 | 2004-12-01 | 21 | 16d |
| 23 | 1.2.3 | **Partner Prescribing Module Requirements** | 14d | 2004-11-22 | 2004-12-09 |  | 0d |
| 24 |  | Document app, general | 1d | 2004-11-22 | 2004-11-22 |  | 0d |
| 25 |  | Document current workflow | 3d | 2004-11-23 | 2004-11-25 | 24 | 0d |
| 26 |  | Document admin flow | 1d | 2004-11-26 | 2004-11-26 | 25 | 0d |
| 27 |  | Identify problem areas | 1d | 2004-11-29 | 2004-11-29 | 26 | 0d |
| 28 |  | Identify patient attributes | 1d | 2004-11-30 | 2004-11-30 | 27 | 0d |
| 29 |  | Identify prescriber attributes | 1d | 2004-12-01 | 2004-12-01 | 28 | 0d |
| 30 |  | Identify pharmacy attributes | 1d | 2004-12-02 | 2004-12-02 | 29 | 0d |
| 31 |  | Update solution document | 2d | 2004-12-03 | 2004-12-06 | 30 | 0d |
| 32 |  | Document versions & release plan | 3d | 2004-12-07 | 2004-12-09 | 31 | 0d |
| 33 |  | Prescribing module requirements & analysis complete | 0d | 2004-12-09 | 2004-12-09 | 32 | 0d |
| 34 | 1.2.4 | **Partner SCRIPT Interface Requirements** | 10d | 2004-12-10 | 2004-12-23 | 33 | 0d |
| 35 |  | Example scenarios review | 3d | 2004-12-10 | 2004-12-14 |  | 84d |
| 36 |  | Implementation guide review | 3d | 2004-12-10 | 2004-12-14 |  | 84d |
| 37 |  | Implementation requirements review | 3d | 2004-12-10 | 2004-12-14 |  | 0d |
| 38 |  | Document messaging attributes | 1d | 2004-12-15 | 2004-12-15 | 37 | 0d |
| 39 |  | Document intended workflow | 2d | 2004-12-16 | 2004-12-17 | 38 | 0d |
| 40 |  | Gap analysis for modified messaging flow | 2d | 2004-12-20 | 2004-12-21 | 39 | 0d |
| 41 |  | Update solution document | 2d | 2004-12-22 | 2004-12-23 | 40 | 0d |
| 42 |  | SCRIPT interface requirements complete | 0d | 2004-12-23 | 2004-12-23 | 41 | 0d |
| 43 | 1.2.5 | **Directory Interface Requirements** | 4d | 2004-11-22 | 2004-11-25 |  | 42d |
| 44 |  | SPI mapping requirements | 2d | 2004-11-22 | 2004-11-23 |  | 99d |
| 45 |  | NCPDP mapping requirements | 2d | 2004-11-22 | 2004-11-23 |  | 99d |
| 46 |  | Service level requirements | 2d | 2004-11-22 | 2004-11-23 |  | 42d |
| 47 |  | Update solution document | 2d | 2004-11-24 | 2004-11-25 | 46 | 42d |
| 48 |  | Directory interface requirements complete | 0d | 2004-11-25 | 2004-11-25 | 47 | 42d |
| 49 | 1.3 | **Design Phase** | 29d | 2004-12-02 | 2005-01-11 | 22 | 16d |
| 50 | 1.3.1 | **Connectivity Design** | 10d | 2004-12-02 | 2004-12-15 | 22 | 19d |
| 51 |  | Document proposed connectivity | 1d | 2004-12-02 | 2004-12-02 |  | 19d |
| 52 |  | Connectivity design approved by network | 2d | 2004-12-03 | 2004-12-06 | 51 | 19d |
| 53 |  | Connectivity design approved by security | 3d | 2004-12-07 | 2004-12-09 | 52 | 19d |
| 54 |  | Connectivity design approved by SureScripts/hoster | 3d | 2004-12-10 | 2004-12-14 | 53 | 19d |
| 55 |  | Update solution document | 1d | 2004-12-15 | 2004-12-15 | 54 | 19d |
| 56 |  | Connectivity design complete | 0d | 2004-12-15 | 2004-12-15 | 55 | 19d |
| 57 | 1.3.2 | **Partner Prescribing Module Design** | 17d | 2004-12-10 | 2005-01-03 | 33 | 52d |
| 58 |  | Create map, module data elements to SCRIPT data elements | 5d | 2004-12-10 | 2004-12-16 |  | 82d |
| 59 |  | Data element validation, size and value limitation | 5d | 2004-12-10 | 2004-12-16 |  | 52d |
| 60 |  | Patient identification algorithm | 3d | 2004-12-17 | 2004-12-21 | 59 | 52d |
| 61 |  | Prescriber identification algorithm | 3d | 2004-12-22 | 2004-12-24 | 60 | 52d |
| 62 |  | Pharmacy identification algorithm | 3d | 2004-12-27 | 2004-12-29 | 61 | 52d |
| 63 |  | Update solution document | 3d | 2004-12-30 | 2005-01-03 | 62 | 52d |
| 64 |  | Prescribing module design complete | 0d | 2005-01-03 | 2005-01-03 | 63 | 52d |
| 65 | 1.3.3 | **Partner SCRIPT Interface Design** | 13d | 2004-12-24 | 2005-01-11 | 42 | 0d |
| 66 |  | Transport design | 3d | 2004-12-24 | 2004-12-28 |  | 0d |
| 67 |  | Message format/content design (and portal) | 6d | 2004-12-29 | 2005-01-05 | 66 | 0d |
| 68 |  | Workflow design | 3d | 2005-01-06 | 2005-01-10 | 67 | 0d |
| 69 |  | Update solution document | 1d | 2005-01-11 | 2005-01-11 | 68 | 0d |
| 70 |  | SCRIPT interface design complete | 0d | 2005-01-11 | 2005-01-11 | 69 | 0d |

| ID | WBS | Task | Duration | Start | Finish | Predecessors | Total float |
| --- | --- | --- | --- | --- | --- | --- | --- |
| 71 | 1.3.4 | **Directory Interface Design** | 10d | 2004-12-02 | 2004-12-15 | 48 | 38d |
| 72 |  | SPI mapping design | 3d | 2004-12-02 | 2004-12-06 |  | 38d |
| 73 |  | NCPDP mapping design | 2d | 2004-12-07 | 2004-12-08 | 72 | 38d |
| 74 |  | Service level design | 2d | 2004-12-09 | 2004-12-10 | 73 | 38d |
| 75 |  | Web service methods TBI by partner | 2d | 2004-12-13 | 2004-12-14 | 74 | 38d |
| 76 |  | Update solution document | 1d | 2004-12-15 | 2004-12-15 | 75 | 38d |
| 77 |  | Directory interface design complete | 0d | 2004-12-15 | 2004-12-15 | 76 | 38d |
| 78 | 1.4 | **Build Phase** | 54d | 2004-12-16 | 2005-03-01 | 56 | 19d |
| 79 |  | Create partner account, Staging | 1d | 2004-12-16 | 2004-12-16 | 12 | 82d |
| 80 |  | Identify/add dev/test users for Admin Console access | 1d | 2004-12-16 | 2004-12-16 | 12 | 82d |
| 81 | 1.4.3 | **Connectivity Build** | 5d | 2004-12-16 | 2004-12-22 | 56 | 46d |
| 82 |  | Staging firewall change | 5d | 2004-12-16 | 2004-12-22 |  | 77d |
| 83 |  | Staging encryption setup | 2d | 2004-12-16 | 2004-12-17 |  | 81d |
| 84 |  | Production firewall change, admin console | 5d | 2004-12-16 | 2004-12-22 |  | 78d |
| 85 |  | Production firewall change, messaging | 5d | 2004-12-16 | 2004-12-22 |  | 46d |
| 86 |  | Production encryption setup | 2d | 2004-12-16 | 2004-12-17 |  | 81d |
| 87 |  | Update solution document | 1d | 2004-12-16 | 2004-12-16 |  | 82d |
| 88 |  | Connectivity build complete | 0d | 2004-12-22 | 2004-12-22 | 85 | 46d |
| 89 |  | Admin Console, User Training | 1d | 2004-12-23 | 2004-12-23 | 82 | 77d |
| 90 | 1.4.5 | **Partner Prescribing Module Build** | 18d | 2005-01-12 | 2005-02-04 | 70, 64 | 46d |
| 91 |  | Scheduled drug, route to print or fax | 3d | 2005-01-12 | 2005-01-14 |  | 46d |
| 92 |  | NEWRX creation | 3d | 2005-01-17 | 2005-01-19 | 91 | 46d |
| 93 |  | REFREQ approved, quantity change | 2d | 2005-01-20 | 2005-01-21 | 92 | 46d |
| 94 |  | REFREQ denied, NEWRX to follow | 4d | 2005-01-24 | 2005-01-27 | 93 | 46d |
| 95 |  | Add new user dataflow to web service client | 4d | 2005-01-28 | 2005-02-02 | 94 | 46d |
| 96 |  | Update solution document | 2d | 2005-02-03 | 2005-02-04 | 95 | 46d |
| 97 |  | Prescribing module build complete | 0d | 2005-02-04 | 2005-02-04 | 96 | 46d |
| 98 | 1.4.6 | **Partner SCRIPT Interface Build** | 35d | 2005-01-12 | 2005-03-01 | 70 | 0d |
| 99 |  | Server dev | 5d | 2005-01-12 | 2005-01-18 |  | 0d |
| 100 |  | Client dev | 3d | 2005-01-19 | 2005-01-21 | 99 | 0d |
| 101 |  | STATUS/ERROR dev | 2d | 2005-01-24 | 2005-01-25 | 100 | 0d |
| 102 |  | NEWRX dev | 7d | 2005-01-26 | 2005-02-03 | 101 | 0d |
| 103 |  | REFREQ dev | 7d | 2005-02-04 | 2005-02-14 | 102 | 0d |
| 104 |  | REFRES dev | 7d | 2005-02-15 | 2005-02-23 | 103 | 0d |
| 105 |  | VERIFY dev | 3d | 2005-02-24 | 2005-02-28 | 104 | 0d |
| 106 |  | Update solution document | 1d | 2005-03-01 | 2005-03-01 | 105 | 0d |
| 107 |  | SCRIPT interface build complete | 0d | 2005-03-01 | 2005-03-01 | 106 | 0d |
| 108 | 1.4.7 | **Directory Interface Build** | 15d | 2004-12-16 | 2005-01-05 | 77 | 38d |
| 109 |  | Web service client dev | 2d | 2004-12-16 | 2004-12-17 |  | 38d |
| 110 |  | Download file dev | 2d | 2004-12-20 | 2004-12-21 | 109 | 38d |
| 111 |  | Import download data to system dev | 3d | 2004-12-22 | 2004-12-24 | 110 | 38d |
| 112 |  | Reconcile download data to system dev | 7d | 2004-12-27 | 2005-01-04 | 111 | 38d |
| 113 |  | SPI lookup dev | 1d | 2004-12-16 | 2004-12-16 |  | 82d |
| 114 |  | NCPDP lookup dev | 1d | 2004-12-16 | 2004-12-16 |  | 76d |
| 115 |  | SPI/NCPDP validation dev | 2d | 2004-12-17 | 2004-12-20 | 114 | 76d |
| 116 |  | Service level lookup dev | 2d | 2004-12-21 | 2004-12-22 | 115 | 76d |
| 117 |  | Service level validation dev | 2d | 2004-12-23 | 2004-12-24 | 116 | 76d |
| 118 |  | Web service add/update methods | 5d | 2004-12-20 | 2004-12-24 | 109 | 76d |
| 119 |  | Update solution document | 1d | 2005-01-05 | 2005-01-05 | 112 | 38d |
| 120 |  | Directory interface build complete | 0d | 2005-01-05 | 2005-01-05 | 119 | 38d |
| 121 | 1.5 | **Test Phase** | 70d | 2004-12-23 | 2005-03-30 |  | 8d |
| 122 | 1.5.1 | **Connectivity Test** | 3d | 2004-12-23 | 2004-12-27 | 88 | 46d |
| 123 |  | Staging firewall connectivity | 1d | 2004-12-23 | 2004-12-23 |  | 77d |
| 124 |  | Staging application connectivity | 1d | 2004-12-23 | 2004-12-23 |  | 77d |
| 125 |  | Staging connectivity, application encryption | 1d | 2004-12-23 | 2004-12-23 |  | 77d |
| 126 |  | Staging connectivity, network encryption | 3d | 2004-12-23 | 2004-12-27 |  | 46d |
| 127 |  | Staging connectivity testing complete | 0d | 2004-12-27 | 2004-12-27 | 126 | 46d |
| 128 |  | Production firewall connectivity | 1d | 2004-12-23 | 2004-12-23 |  | 77d |
| 129 |  | Production application connectivity | 1d | 2004-12-23 | 2004-12-23 |  | 77d |
| 130 |  | Production connectivity, application encryption | 1d | 2004-12-23 | 2004-12-23 |  | 77d |
| 131 |  | Production connectivity, network encryption | 3d | 2004-12-23 | 2004-12-27 |  | 73d |
| 132 |  | Production connectivity testing complete | 0d | 2004-12-27 | 2004-12-27 | 131 | 73d |
| 133 | 1.5.2 | **Partner SCRIPT Interface Test** | 7d | 2005-03-02 | 2005-03-10 | 107, 127 | 0d |
| 134 |  | Partner system testing | 7d | 2005-03-02 | 2005-03-10 |  | 0d |
| 135 |  | SCRIPT interface testing complete | 0d | 2005-03-10 | 2005-03-10 | 134 | 0d |
| 136 | 1.5.3 | **Directory Interface Test** | 8d | 2005-01-06 | 2005-01-17 | 120 | 38d |
| 137 |  | Download file to partner system | 1d | 2005-01-06 | 2005-01-06 |  | 38d |
| 138 |  | Import download data to partner system | 2d | 2005-01-07 | 2005-01-10 | 137 | 38d |
| 139 |  | Download data reconciled successfully | 2d | 2005-01-11 | 2005-01-12 | 138 | 38d |
| 140 |  | Web service add/update entries successfully | 1d | 2005-01-13 | 2005-01-13 | 139 | 38d |

| ID | WBS | Task | Duration | Start | Finish | Predecessors | Total float |
| --- | --- | --- | --- | --- | --- | --- | --- |
| 141 |  | Admin module add/update user successfully | 2d | 2005-01-14 | 2005-01-17 | 140 | 38d |
| 142 |  | Directory interface testing complete | 0d | 2005-01-17 | 2005-01-17 | 141 | 38d |
| 143 |  | Pre-Certification testing complete | 0d | 2005-03-10 | 2005-03-10 | 135, 142 | 0d |
| 144 | 1.5.5 | **Certification** | 14d | 2005-03-11 | 2005-03-30 | 143 | 0d |
| 145 |  | Detailed message review, element use | 2d | 2005-03-11 | 2005-03-14 |  | 20d |
| 146 |  | Detailed workflow review, screenshots | 2d | 2005-03-11 | 2005-03-14 |  | 0d |
| 147 |  | Config test platform for partner certification | 1d | 2005-03-11 | 2005-03-11 |  | 21d |
| 148 |  | NEWRX tests | 2d | 2005-03-15 | 2005-03-16 | 146 | 0d |
| 149 |  | REFREQ tests | 2d | 2005-03-17 | 2005-03-18 | 148 | 0d |
| 150 |  | REFRES tests | 2d | 2005-03-21 | 2005-03-22 | 149 | 0d |
| 151 |  | Scheduled drug test | 1d | 2005-03-23 | 2005-03-23 | 150 | 0d |
| 152 |  | Free standing ERROR test | 1d | 2005-03-24 | 2005-03-24 | 151 | 0d |
| 153 |  | Failover test, to fax | 1d | 2005-03-25 | 2005-03-25 | 152 | 0d |
| 154 |  | Directory web services tests | 1d | 2005-03-28 | 2005-03-28 | 153 | 0d |
| 155 |  | Final review of all messages and screenshots | 2d | 2005-03-29 | 2005-03-30 | 154 | 0d |
| 156 |  | Partner questionnaire to SureScripts | 1d | 2005-03-23 | 2005-03-23 | 150 | 13d |
| 157 |  | Certification complete | 0d | 2005-03-30 | 2005-03-30 | 155 | 0d |
| 158 | 1.6 | **Production Readiness Phase** | 8d | 2005-03-31 | 2005-04-11 | 157 | 0d |
| 159 | 1.6.1 | **Setup** | 7d | 2005-03-31 | 2005-04-08 |  | 0d |
| 160 |  | Partner SCRIPT interface production deployment | 3d | 2005-03-31 | 2005-04-04 |  | 0d |
| 161 |  | Partner directory interface production deployment | 1d | 2005-04-05 | 2005-04-05 | 160 | 0d |
| 162 |  | SureScripts messaging, server setup | 1d | 2005-04-06 | 2005-04-06 | 161 | 0d |
| 163 |  | Identify/add support users for Admin Console access | 1d | 2005-04-07 | 2005-04-07 | 162 | 0d |
| 164 |  | Initial partner directory data loaded | 1d | 2005-04-07 | 2005-04-07 | 162 | 0d |
| 165 |  | Reconfirm network connectivity | 1d | 2005-04-08 | 2005-04-08 | 164, 132 | 0d |
| 166 |  | Production setup complete | 0d | 2005-04-08 | 2005-04-08 | 165 | 0d |
| 167 | 1.6.2 | **Support** | 8d | 2005-03-31 | 2005-04-11 |  | 0d |
| 168 |  | Admin Console, User Training | 1d | 2005-04-08 | 2005-04-08 | 163 | 0d |
| 169 |  | Brief partner on SureScripts support services | 1d | 2005-04-11 | 2005-04-11 | 168 | 0d |
| 170 |  | All partner support email/contacts received | 2d | 2005-03-31 | 2005-04-01 |  | 5d |
| 171 |  | All partner support escalation contacts received | 2d | 2005-03-31 | 2005-04-01 |  | 5d |
| 172 |  | All partner support contacts added to SureScripts Support System | 1d | 2005-04-04 | 2005-04-04 | 170, 171 | 5d |
| 173 |  | Implementation Closeout Meeting | 1d | 2005-04-11 | 2005-04-11 | 157, 166 | 0d |

## Version 2 (saved 2005-08-08, file SureScripts Partner Implementation 2Q2005.mpp)

Last finish 2005-04-11 → 2005-06-13 (+63d).

Added:

| ID | Task | Duration | Start | Finish | Predecessors |
| --- | --- | --- | --- | --- | --- |
| 5 | Operating Level Agreement delivered | 0d | 2005-01-10 | 2005-01-10 | 4 |
| 145 | Operating Level Agreement Executed | 0d | 2005-01-10 | 2005-01-10 | 5 |

Changed:

| ID | Task | Start | Finish | Predecessors | Other |
| --- | --- | --- | --- | --- | --- |
| 1 | **SureScripts Implementation Project** | 2004-11-01 → 2005-01-03 (+63d) | 2005-04-11 → 2005-06-13 (+63d) |  |  |
| 2 | **Initiation Phase** | 2004-11-01 → 2005-01-03 (+63d) | 2004-11-19 → 2005-01-21 (+63d) |  |  |
| 3 | NDA executed | 2004-11-01 → 2005-01-03 (+63d) | 2004-11-05 → 2005-01-07 (+63d) |  | constraint none → start no earlier than 2005-01-03 |
| 4 | Deliver implementation documentation | 2004-11-08 → 2005-01-10 (+63d) | 2004-11-08 → 2005-01-10 (+63d) |  |  |
| 6 | Contract ratified | 2004-11-08 → 2005-01-10 (+63d) | 2004-11-08 → 2005-01-10 (+63d) | 4 → 5 |  |
| 7 | **Project Planning** | 2004-11-09 → 2005-01-11 (+63d) | 2004-11-19 → 2005-01-21 (+63d) |  |  |
| 8 | Revise implementation template | 2004-11-09 → 2005-01-11 (+63d) | 2004-11-15 → 2005-01-17 (+63d) |  |  |
| 9 | Distribute for comment | 2004-11-16 → 2005-01-18 (+63d) | 2004-11-16 → 2005-01-18 (+63d) |  |  |
| 10 | Review/modify plan | 2004-11-17 → 2005-01-19 (+63d) | 2004-11-19 → 2005-01-21 (+63d) |  |  |
| 11 | Implementation plan complete | 2004-11-19 → 2005-01-21 (+63d) | 2004-11-19 → 2005-01-21 (+63d) |  |  |
| 12 | **Requirements & Analysis Phase** | 2004-11-22 → 2005-01-24 (+63d) | 2004-12-23 → 2005-02-24 (+63d) |  |  |
| 13 | Initial implementation call | 2004-11-22 → 2005-01-24 (+63d) | 2004-11-22 → 2005-01-24 (+63d) |  |  |
| 14 | **Connectivity Requirements** | 2004-11-22 → 2005-01-24 (+63d) | 2004-12-01 → 2005-02-02 (+63d) |  |  |
| 15 | Define environments | 2004-11-22 → 2005-01-24 (+63d) | 2004-11-24 → 2005-01-26 (+63d) |  |  |
| 16 | Assess aggregator requirements | 2004-11-22 → 2005-01-24 (+63d) | 2004-11-24 → 2005-01-26 (+63d) |  |  |
| 17 | Assess connectivity mgmt | 2004-11-22 → 2005-01-24 (+63d) | 2004-11-24 → 2005-01-26 (+63d) |  |  |
| 18 | Assess DNS requirements | 2004-11-22 → 2005-01-24 (+63d) | 2004-11-24 → 2005-01-26 (+63d) |  |  |
| 19 | Assess throughput requirements | 2004-11-22 → 2005-01-24 (+63d) | 2004-11-24 → 2005-01-26 (+63d) |  |  |
| 20 | Assess environment requirements/impact | 2004-11-25 → 2005-01-27 (+63d) | 2004-11-26 → 2005-01-28 (+63d) |  |  |
| 21 | Update solution document w/requirements & assumptions | 2004-11-29 → 2005-01-31 (+63d) | 2004-11-30 → 2005-02-01 (+63d) |  |  |
| 22 | Conduct connectivity risk analysis | 2004-12-01 → 2005-02-02 (+63d) | 2004-12-01 → 2005-02-02 (+63d) |  |  |
| 23 | Connectivity requirements complete | 2004-12-01 → 2005-02-02 (+63d) | 2004-12-01 → 2005-02-02 (+63d) |  |  |
| 24 | **Partner Prescribing Module Requirements** | 2004-11-22 → 2005-01-24 (+63d) | 2004-12-09 → 2005-02-10 (+63d) |  |  |
| 25 | Document app, general | 2004-11-22 → 2005-01-24 (+63d) | 2004-11-22 → 2005-01-24 (+63d) |  |  |
| 26 | Document current workflow | 2004-11-23 → 2005-01-25 (+63d) | 2004-11-25 → 2005-01-27 (+63d) |  |  |
| 27 | Document admin flow | 2004-11-26 → 2005-01-28 (+63d) | 2004-11-26 → 2005-01-28 (+63d) |  |  |
| 28 | Identify problem areas | 2004-11-29 → 2005-01-31 (+63d) | 2004-11-29 → 2005-01-31 (+63d) |  |  |
| 29 | Identify patient attributes | 2004-11-30 → 2005-02-01 (+63d) | 2004-11-30 → 2005-02-01 (+63d) |  |  |
| 30 | Identify prescriber attributes | 2004-12-01 → 2005-02-02 (+63d) | 2004-12-01 → 2005-02-02 (+63d) |  |  |
| 31 | Identify pharmacy attributes | 2004-12-02 → 2005-02-03 (+63d) | 2004-12-02 → 2005-02-03 (+63d) |  |  |
| 32 | Update solution document | 2004-12-03 → 2005-02-04 (+63d) | 2004-12-06 → 2005-02-07 (+63d) |  |  |
| 33 | Document versions & release plan | 2004-12-07 → 2005-02-08 (+63d) | 2004-12-09 → 2005-02-10 (+63d) |  |  |
| 34 | Prescribing module requirements & analysis complete | 2004-12-09 → 2005-02-10 (+63d) | 2004-12-09 → 2005-02-10 (+63d) |  |  |
| 35 | **Partner SCRIPT Interface Requirements** | 2004-12-10 → 2005-02-11 (+63d) | 2004-12-23 → 2005-02-24 (+63d) |  |  |
| 36 | Example scenarios review | 2004-12-10 → 2005-02-11 (+63d) | 2004-12-14 → 2005-02-15 (+63d) |  |  |
| 37 | Implementation guide review | 2004-12-10 → 2005-02-11 (+63d) | 2004-12-14 → 2005-02-15 (+63d) |  |  |
| 38 | Implementation requirements review | 2004-12-10 → 2005-02-11 (+63d) | 2004-12-14 → 2005-02-15 (+63d) |  |  |
| 39 | Document messaging attributes | 2004-12-15 → 2005-02-16 (+63d) | 2004-12-15 → 2005-02-16 (+63d) |  |  |
| 40 | Document intended workflow | 2004-12-16 → 2005-02-17 (+63d) | 2004-12-17 → 2005-02-18 (+63d) |  |  |
| 41 | Gap analysis for modified messaging flow | 2004-12-20 → 2005-02-21 (+63d) | 2004-12-21 → 2005-02-22 (+63d) |  |  |
| 42 | Update solution document | 2004-12-22 → 2005-02-23 (+63d) | 2004-12-23 → 2005-02-24 (+63d) |  |  |
| 43 | SCRIPT interface requirements complete | 2004-12-23 → 2005-02-24 (+63d) | 2004-12-23 → 2005-02-24 (+63d) |  |  |
| 44 | **Directory Interface Requirements** | 2004-11-22 → 2005-01-24 (+63d) | 2004-11-25 → 2005-01-27 (+63d) |  |  |
| 45 | SPI mapping requirements | 2004-11-22 → 2005-01-24 (+63d) | 2004-11-23 → 2005-01-25 (+63d) |  |  |
| 46 | NCPDP mapping requirements | 2004-11-22 → 2005-01-24 (+63d) | 2004-11-23 → 2005-01-25 (+63d) |  |  |
| 47 | Service level requirements | 2004-11-22 → 2005-01-24 (+63d) | 2004-11-23 → 2005-01-25 (+63d) |  |  |
| 48 | Update solution document | 2004-11-24 → 2005-01-26 (+63d) | 2004-11-25 → 2005-01-27 (+63d) |  |  |
| 49 | Directory interface requirements complete | 2004-11-25 → 2005-01-27 (+63d) | 2004-11-25 → 2005-01-27 (+63d) |  |  |
| 50 | **Design Phase** | 2004-12-02 → 2005-02-03 (+63d) | 2005-01-11 → 2005-03-15 (+63d) |  |  |
| 51 | **Connectivity Design** | 2004-12-02 → 2005-02-03 (+63d) | 2004-12-15 → 2005-02-16 (+63d) |  |  |
| 52 | Document proposed connectivity | 2004-12-02 → 2005-02-03 (+63d) | 2004-12-02 → 2005-02-03 (+63d) |  |  |
| 53 | Connectivity design approved by network | 2004-12-03 → 2005-02-04 (+63d) | 2004-12-06 → 2005-02-07 (+63d) |  |  |
| 54 | Connectivity design approved by security | 2004-12-07 → 2005-02-08 (+63d) | 2004-12-09 → 2005-02-10 (+63d) |  |  |
| 55 | Connectivity design approved by SureScripts/hoster | 2004-12-10 → 2005-02-11 (+63d) | 2004-12-14 → 2005-02-15 (+63d) |  |  |
| 56 | Update solution document | 2004-12-15 → 2005-02-16 (+63d) | 2004-12-15 → 2005-02-16 (+63d) |  |  |
| 57 | Connectivity design complete | 2004-12-15 → 2005-02-16 (+63d) | 2004-12-15 → 2005-02-16 (+63d) |  |  |
| 58 | **Partner Prescribing Module Design** | 2004-12-10 → 2005-02-11 (+63d) | 2005-01-03 → 2005-03-07 (+63d) |  |  |
| 59 | Create map, module data elements to SCRIPT data elements | 2004-12-10 → 2005-02-11 (+63d) | 2004-12-16 → 2005-02-17 (+63d) |  |  |
| 60 | Data element validation, size and value limitation | 2004-12-10 → 2005-02-11 (+63d) | 2004-12-16 → 2005-02-17 (+63d) |  |  |
| 61 | Patient identification algorithm | 2004-12-17 → 2005-02-18 (+63d) | 2004-12-21 → 2005-02-22 (+63d) |  |  |
| 62 | Prescriber identification algorithm | 2004-12-22 → 2005-02-23 (+63d) | 2004-12-24 → 2005-02-25 (+63d) |  |  |
| 63 | Pharmacy identification algorithm | 2004-12-27 → 2005-02-28 (+63d) | 2004-12-29 → 2005-03-02 (+63d) |  |  |
| 64 | Update solution document | 2004-12-30 → 2005-03-03 (+63d) | 2005-01-03 → 2005-03-07 (+63d) |  |  |
| 65 | Prescribing module design complete | 2005-01-03 → 2005-03-07 (+63d) | 2005-01-03 → 2005-03-07 (+63d) |  |  |
| 66 | **Partner SCRIPT Interface Design** | 2004-12-24 → 2005-02-25 (+63d) | 2005-01-11 → 2005-03-15 (+63d) |  |  |
| 67 | Transport design | 2004-12-24 → 2005-02-25 (+63d) | 2004-12-28 → 2005-03-01 (+63d) |  |  |
| 68 | Message format/content design (and portal) | 2004-12-29 → 2005-03-02 (+63d) | 2005-01-05 → 2005-03-09 (+63d) |  |  |
| 69 | Workflow design | 2005-01-06 → 2005-03-10 (+63d) | 2005-01-10 → 2005-03-14 (+63d) |  |  |
| 70 | Update solution document | 2005-01-11 → 2005-03-15 (+63d) | 2005-01-11 → 2005-03-15 (+63d) |  |  |
| 71 | SCRIPT interface design complete | 2005-01-11 → 2005-03-15 (+63d) | 2005-01-11 → 2005-03-15 (+63d) |  |  |

| ID | Task | Start | Finish | Duration |
| --- | --- | --- | --- | --- |
| 72 | **Directory Interface Design** | 2004-12-02 → 2005-02-03 (+63d) | 2004-12-15 → 2005-02-16 (+63d) |  |
| 73 | SPI mapping design | 2004-12-02 → 2005-02-03 (+63d) | 2004-12-06 → 2005-02-07 (+63d) |  |
| 74 | NCPDP mapping design | 2004-12-07 → 2005-02-08 (+63d) | 2004-12-08 → 2005-02-09 (+63d) |  |
| 75 | Service level design | 2004-12-09 → 2005-02-10 (+63d) | 2004-12-10 → 2005-02-11 (+63d) |  |
| 76 | Web service methods TBI by partner | 2004-12-13 → 2005-02-14 (+63d) | 2004-12-14 → 2005-02-15 (+63d) |  |
| 77 | Update solution document | 2004-12-15 → 2005-02-16 (+63d) | 2004-12-15 → 2005-02-16 (+63d) |  |
| 78 | Directory interface design complete | 2004-12-15 → 2005-02-16 (+63d) | 2004-12-15 → 2005-02-16 (+63d) |  |
| 79 | **Build Phase** | 2004-12-16 → 2005-02-17 (+63d) | 2005-03-01 → 2005-05-03 (+63d) |  |
| 80 | Create partner account, Staging | 2004-12-16 → 2005-02-17 (+63d) | 2004-12-16 → 2005-02-17 (+63d) |  |
| 81 | Identify/add dev/test users for Admin Console access | 2004-12-16 → 2005-02-17 (+63d) | 2004-12-16 → 2005-02-17 (+63d) |  |
| 82 | **Connectivity Build** | 2004-12-16 → 2005-02-17 (+63d) | 2004-12-22 → 2005-02-23 (+63d) |  |
| 83 | Staging firewall change | 2004-12-16 → 2005-02-17 (+63d) | 2004-12-22 → 2005-02-23 (+63d) |  |
| 84 | Staging encryption setup | 2004-12-16 → 2005-02-17 (+63d) | 2004-12-17 → 2005-02-18 (+63d) |  |
| 85 | Production firewall change, admin console | 2004-12-16 → 2005-02-17 (+63d) | 2004-12-22 → 2005-02-23 (+63d) |  |
| 86 | Production firewall change, messaging | 2004-12-16 → 2005-02-17 (+63d) | 2004-12-22 → 2005-02-23 (+63d) |  |
| 87 | Production encryption setup | 2004-12-16 → 2005-02-17 (+63d) | 2004-12-17 → 2005-02-18 (+63d) |  |
| 88 | Update solution document | 2004-12-16 → 2005-02-17 (+63d) | 2004-12-16 → 2005-02-17 (+63d) |  |
| 89 | Connectivity build complete | 2004-12-22 → 2005-02-23 (+63d) | 2004-12-22 → 2005-02-23 (+63d) |  |
| 90 | Admin Console, User Training | 2004-12-23 → 2005-02-24 (+63d) | 2004-12-23 → 2005-02-24 (+63d) |  |
| 91 | **Partner Prescribing Module Build** | 2005-01-12 → 2005-03-16 (+63d) | 2005-02-04 → 2005-04-08 (+63d) |  |
| 92 | Scheduled drug, route to print or fax | 2005-01-12 → 2005-03-16 (+63d) | 2005-01-14 → 2005-03-18 (+63d) |  |
| 93 | NEWRX creation | 2005-01-17 → 2005-03-21 (+63d) | 2005-01-19 → 2005-03-23 (+63d) |  |
| 94 | REFREQ approved, quantity change | 2005-01-20 → 2005-03-24 (+63d) | 2005-01-21 → 2005-03-25 (+63d) |  |
| 95 | REFREQ denied, NEWRX to follow | 2005-01-24 → 2005-03-28 (+63d) | 2005-01-27 → 2005-03-31 (+63d) |  |
| 96 | Add new user dataflow to web service client | 2005-01-28 → 2005-04-01 (+63d) | 2005-02-02 → 2005-04-06 (+63d) |  |
| 97 | Update solution document | 2005-02-03 → 2005-04-07 (+63d) | 2005-02-04 → 2005-04-08 (+63d) |  |
| 98 | Prescribing module build complete | 2005-02-04 → 2005-04-08 (+63d) | 2005-02-04 → 2005-04-08 (+63d) |  |
| 99 | **Partner SCRIPT Interface Build** | 2005-01-12 → 2005-03-16 (+63d) | 2005-03-01 → 2005-05-03 (+63d) |  |
| 100 | Server dev | 2005-01-12 → 2005-03-16 (+63d) | 2005-01-18 → 2005-03-22 (+63d) |  |
| 101 | Client dev | 2005-01-19 → 2005-03-23 (+63d) | 2005-01-21 → 2005-03-25 (+63d) |  |
| 102 | STATUS/ERROR dev | 2005-01-24 → 2005-03-28 (+63d) | 2005-01-25 → 2005-03-29 (+63d) |  |
| 103 | NEWRX dev | 2005-01-26 → 2005-03-30 (+63d) | 2005-02-03 → 2005-04-07 (+63d) |  |
| 104 | REFREQ dev | 2005-02-04 → 2005-04-08 (+63d) | 2005-02-14 → 2005-04-18 (+63d) |  |
| 105 | REFRES dev | 2005-02-15 → 2005-04-19 (+63d) | 2005-02-23 → 2005-04-27 (+63d) |  |
| 106 | VERIFY dev | 2005-02-24 → 2005-04-28 (+63d) | 2005-02-28 → 2005-05-02 (+63d) |  |
| 107 | Update solution document | 2005-03-01 → 2005-05-03 (+63d) | 2005-03-01 → 2005-05-03 (+63d) |  |
| 108 | SCRIPT interface build complete | 2005-03-01 → 2005-05-03 (+63d) | 2005-03-01 → 2005-05-03 (+63d) |  |
| 109 | **Directory Interface Build** | 2004-12-16 → 2005-02-17 (+63d) | 2005-01-05 → 2005-03-09 (+63d) |  |
| 110 | Web service client dev | 2004-12-16 → 2005-02-17 (+63d) | 2004-12-17 → 2005-02-18 (+63d) |  |
| 111 | Download file dev | 2004-12-20 → 2005-02-21 (+63d) | 2004-12-21 → 2005-02-22 (+63d) |  |
| 112 | Import download data to system dev | 2004-12-22 → 2005-02-23 (+63d) | 2004-12-24 → 2005-02-25 (+63d) |  |
| 113 | Reconcile download data to system dev | 2004-12-27 → 2005-02-28 (+63d) | 2005-01-04 → 2005-03-08 (+63d) |  |
| 114 | SPI lookup dev | 2004-12-16 → 2005-02-17 (+63d) | 2004-12-16 → 2005-02-17 (+63d) |  |
| 115 | NCPDP lookup dev | 2004-12-16 → 2005-02-17 (+63d) | 2004-12-16 → 2005-02-17 (+63d) |  |
| 116 | SPI/NCPDP validation dev | 2004-12-17 → 2005-02-18 (+63d) | 2004-12-20 → 2005-02-21 (+63d) |  |
| 117 | Service level lookup dev | 2004-12-21 → 2005-02-22 (+63d) | 2004-12-22 → 2005-02-23 (+63d) |  |
| 118 | Service level validation dev | 2004-12-23 → 2005-02-24 (+63d) | 2004-12-24 → 2005-02-25 (+63d) |  |
| 119 | Web service add/update methods | 2004-12-20 → 2005-02-21 (+63d) | 2004-12-24 → 2005-02-25 (+63d) |  |
| 120 | Update solution document | 2005-01-05 → 2005-03-09 (+63d) | 2005-01-05 → 2005-03-09 (+63d) |  |
| 121 | Directory interface build complete | 2005-01-05 → 2005-03-09 (+63d) | 2005-01-05 → 2005-03-09 (+63d) |  |
| 122 | **Test Phase** | 2004-12-23 → 2005-01-10 (+18d) | 2005-03-30 → 2005-06-01 (+63d) | 70d → 102d |
| 123 | **Connectivity Test** | 2004-12-23 → 2005-02-24 (+63d) | 2004-12-27 → 2005-02-28 (+63d) |  |
| 124 | Staging firewall connectivity | 2004-12-23 → 2005-02-24 (+63d) | 2004-12-23 → 2005-02-24 (+63d) |  |
| 125 | Staging application connectivity | 2004-12-23 → 2005-02-24 (+63d) | 2004-12-23 → 2005-02-24 (+63d) |  |
| 126 | Staging connectivity, application encryption | 2004-12-23 → 2005-02-24 (+63d) | 2004-12-23 → 2005-02-24 (+63d) |  |
| 127 | Staging connectivity, network encryption | 2004-12-23 → 2005-02-24 (+63d) | 2004-12-27 → 2005-02-28 (+63d) |  |
| 128 | Staging connectivity testing complete | 2004-12-27 → 2005-02-28 (+63d) | 2004-12-27 → 2005-02-28 (+63d) |  |
| 129 | Production firewall connectivity | 2004-12-23 → 2005-02-24 (+63d) | 2004-12-23 → 2005-02-24 (+63d) |  |
| 130 | Production application connectivity | 2004-12-23 → 2005-02-24 (+63d) | 2004-12-23 → 2005-02-24 (+63d) |  |
| 131 | Production connectivity, application encryption | 2004-12-23 → 2005-02-24 (+63d) | 2004-12-23 → 2005-02-24 (+63d) |  |
| 132 | Production connectivity, network encryption | 2004-12-23 → 2005-02-24 (+63d) | 2004-12-27 → 2005-02-28 (+63d) |  |
| 133 | Production connectivity testing complete | 2004-12-27 → 2005-02-28 (+63d) | 2004-12-27 → 2005-02-28 (+63d) |  |
| 134 | **Partner SCRIPT Interface Test** | 2005-03-02 → 2005-05-04 (+63d) | 2005-03-10 → 2005-05-12 (+63d) |  |
| 135 | Partner system testing | 2005-03-02 → 2005-05-04 (+63d) | 2005-03-10 → 2005-05-12 (+63d) |  |
| 136 | SCRIPT interface testing complete | 2005-03-10 → 2005-05-12 (+63d) | 2005-03-10 → 2005-05-12 (+63d) |  |
| 137 | **Directory Interface Test** | 2005-01-06 → 2005-03-10 (+63d) | 2005-01-17 → 2005-03-21 (+63d) |  |
| 138 | Download file to partner system | 2005-01-06 → 2005-03-10 (+63d) | 2005-01-06 → 2005-03-10 (+63d) |  |
| 139 | Import download data to partner system | 2005-01-07 → 2005-03-11 (+63d) | 2005-01-10 → 2005-03-14 (+63d) |  |
| 140 | Download data reconciled successfully | 2005-01-11 → 2005-03-15 (+63d) | 2005-01-12 → 2005-03-16 (+63d) |  |
| 141 | Web service add/update entries successfully | 2005-01-13 → 2005-03-17 (+63d) | 2005-01-13 → 2005-03-17 (+63d) |  |

| ID | Task | Start | Finish | Predecessors |
| --- | --- | --- | --- | --- |
| 142 | Admin module add/update user successfully | 2005-01-14 → 2005-03-18 (+63d) | 2005-01-17 → 2005-03-21 (+63d) |  |
| 143 | Directory interface testing complete | 2005-01-17 → 2005-03-21 (+63d) | 2005-01-17 → 2005-03-21 (+63d) |  |
| 144 | Pre-Certification testing complete | 2005-03-10 → 2005-05-12 (+63d) | 2005-03-10 → 2005-05-12 (+63d) |  |
| 146 | **Certification** | 2005-03-11 → 2005-05-13 (+63d) | 2005-03-30 → 2005-06-01 (+63d) | 144 → 145, 144 |
| 147 | Detailed message review, element use | 2005-03-11 → 2005-05-13 (+63d) | 2005-03-14 → 2005-05-16 (+63d) |  |
| 148 | Detailed workflow review, screenshots | 2005-03-11 → 2005-05-13 (+63d) | 2005-03-14 → 2005-05-16 (+63d) |  |
| 149 | Config test platform for partner certification | 2005-03-11 → 2005-05-13 (+63d) | 2005-03-11 → 2005-05-13 (+63d) |  |
| 150 | NEWRX tests | 2005-03-15 → 2005-05-17 (+63d) | 2005-03-16 → 2005-05-18 (+63d) |  |
| 151 | REFREQ tests | 2005-03-17 → 2005-05-19 (+63d) | 2005-03-18 → 2005-05-20 (+63d) |  |
| 152 | REFRES tests | 2005-03-21 → 2005-05-23 (+63d) | 2005-03-22 → 2005-05-24 (+63d) |  |
| 153 | Scheduled drug test | 2005-03-23 → 2005-05-25 (+63d) | 2005-03-23 → 2005-05-25 (+63d) |  |
| 154 | Free standing ERROR test | 2005-03-24 → 2005-05-26 (+63d) | 2005-03-24 → 2005-05-26 (+63d) |  |
| 155 | Failover test, to fax | 2005-03-25 → 2005-05-27 (+63d) | 2005-03-25 → 2005-05-27 (+63d) |  |
| 156 | Directory web services tests | 2005-03-28 → 2005-05-30 (+63d) | 2005-03-28 → 2005-05-30 (+63d) |  |
| 157 | Final review of all messages and screenshots | 2005-03-29 → 2005-05-31 (+63d) | 2005-03-30 → 2005-06-01 (+63d) |  |
| 158 | Partner questionnaire to SureScripts | 2005-03-23 → 2005-05-25 (+63d) | 2005-03-23 → 2005-05-25 (+63d) |  |
| 159 | Certification complete | 2005-03-30 → 2005-06-01 (+63d) | 2005-03-30 → 2005-06-01 (+63d) |  |
| 160 | **Production Readiness Phase** | 2005-03-31 → 2005-06-02 (+63d) | 2005-04-11 → 2005-06-13 (+63d) |  |
| 161 | **Setup** | 2005-03-31 → 2005-06-02 (+63d) | 2005-04-08 → 2005-06-10 (+63d) |  |
| 162 | Partner SCRIPT interface production deployment | 2005-03-31 → 2005-06-02 (+63d) | 2005-04-04 → 2005-06-06 (+63d) |  |
| 163 | Partner directory interface production deployment | 2005-04-05 → 2005-06-07 (+63d) | 2005-04-05 → 2005-06-07 (+63d) |  |
| 164 | SureScripts messaging, server setup | 2005-04-06 → 2005-06-08 (+63d) | 2005-04-06 → 2005-06-08 (+63d) |  |
| 165 | Identify/add support users for Admin Console access | 2005-04-07 → 2005-06-09 (+63d) | 2005-04-07 → 2005-06-09 (+63d) |  |
| 166 | Initial partner directory data loaded | 2005-04-07 → 2005-06-09 (+63d) | 2005-04-07 → 2005-06-09 (+63d) |  |
| 167 | Reconfirm network connectivity | 2005-04-08 → 2005-06-10 (+63d) | 2005-04-08 → 2005-06-10 (+63d) |  |
| 168 | Production setup complete | 2005-04-08 → 2005-06-10 (+63d) | 2005-04-08 → 2005-06-10 (+63d) |  |
| 169 | **Support** | 2005-03-31 → 2005-06-02 (+63d) | 2005-04-11 → 2005-06-13 (+63d) |  |
| 170 | Admin Console, User Training | 2005-04-08 → 2005-06-10 (+63d) | 2005-04-08 → 2005-06-10 (+63d) |  |
| 171 | Brief partner on SureScripts support services | 2005-04-11 → 2005-06-13 (+63d) | 2005-04-11 → 2005-06-13 (+63d) |  |
| 172 | All partner support email/contacts received | 2005-03-31 → 2005-06-02 (+63d) | 2005-04-01 → 2005-06-03 (+63d) |  |
| 173 | All partner support escalation contacts received | 2005-03-31 → 2005-06-02 (+63d) | 2005-04-01 → 2005-06-03 (+63d) |  |
| 174 | All partner support contacts added to SureScripts Support System | 2005-04-04 → 2005-06-06 (+63d) | 2005-04-04 → 2005-06-06 (+63d) |  |
| 175 | Implementation Closeout Meeting | 2005-04-11 → 2005-06-13 (+63d) | 2005-04-11 → 2005-06-13 (+63d) |  |

## Version 3 (data date 2006-02-02, saved 2006-02-02, file SureScripts_Medent_Imp.mpp)

Last finish 2005-06-13 → 2006-06-27 (+379d).

Changed:

| ID | Task | Start | Finish | Predecessors | Other |
| --- | --- | --- | --- | --- | --- |
| 1 | **Medent- SureScripts Implementation Project** | 2005-01-03 → 2006-01-17 (+379d) | 2005-06-13 → 2006-06-27 (+379d) |  | was named SureScripts Implementation Project |
| 2 | **Initiation Phase** | 2005-01-03 → 2006-01-17 (+379d) | 2005-01-21 → 2006-02-06 (+381d) |  |  |
| 3 | NDA executed | 2005-01-03 → 2006-01-17 (+379d) | 2005-01-07 → 2006-01-23 (+381d) |  | constraint start no earlier than 2005-01-03 → start no earlier than 2006-01-17 |
| 4 | Deliver implementation documentation | 2005-01-10 → 2006-01-24 (+379d) | 2005-01-10 → 2006-01-24 (+379d) |  |  |
| 5 | Contract ratified | 2005-01-10 → 2006-01-24 (+379d) | 2005-01-10 → 2006-01-24 (+379d) | 6 → 4 |  |
| 6 | Deliver OLA | 2005-01-10 → 2006-01-24 (+379d) | 2005-01-10 → 2006-01-24 (+379d) | 4 → 5 | was named Operating Level Agreement delivered; resources none → SSS |
| 7 | **Project Planning** | 2005-01-11 → 2006-01-25 (+379d) | 2005-01-21 → 2006-02-06 (+381d) | 5 → 6 |  |
| 8 | Revise implementation template | 2005-01-11 → 2006-01-25 (+379d) | 2005-01-17 → 2006-01-31 (+379d) |  |  |
| 9 | Distribute for comment | 2005-01-18 → 2006-02-01 (+379d) | 2005-01-18 → 2006-02-01 (+379d) |  |  |
| 10 | Review/modify plan | 2005-01-19 → 2006-02-02 (+379d) | 2005-01-21 → 2006-02-06 (+381d) |  |  |
| 11 | Implementation plan complete | 2005-01-21 → 2006-02-06 (+381d) | 2005-01-21 → 2006-02-06 (+381d) |  |  |
| 12 | **Requirements & Analysis Phase** | 2005-01-24 → 2006-02-07 (+379d) | 2005-02-24 → 2006-03-10 (+379d) |  |  |
| 13 | Initial implementation call | 2005-01-24 → 2006-02-07 (+379d) | 2005-01-24 → 2006-02-07 (+379d) |  | constraint none → start no earlier than 2006-02-07 |
| 14 | **Connectivity Requirements** | 2005-01-24 → 2006-02-07 (+379d) | 2005-02-02 → 2006-02-16 (+379d) |  |  |
| 15 | Define environments | 2005-01-24 → 2006-02-07 (+379d) | 2005-01-26 → 2006-02-09 (+379d) |  |  |
| 16 | Assess aggregator requirements | 2005-01-24 → 2006-02-07 (+379d) | 2005-01-26 → 2006-02-09 (+379d) |  |  |
| 17 | Assess connectivity mgmt | 2005-01-24 → 2006-02-07 (+379d) | 2005-01-26 → 2006-02-09 (+379d) |  |  |
| 18 | Assess DNS requirements | 2005-01-24 → 2006-02-07 (+379d) | 2005-01-26 → 2006-02-09 (+379d) |  |  |
| 19 | Assess throughput requirements | 2005-01-24 → 2006-02-07 (+379d) | 2005-01-26 → 2006-02-09 (+379d) |  |  |
| 20 | Assess environment requirements/impact | 2005-01-27 → 2006-02-10 (+379d) | 2005-01-28 → 2006-02-13 (+381d) |  |  |
| 21 | Update solution document w/requirements & assumptions | 2005-01-31 → 2006-02-14 (+379d) | 2005-02-01 → 2006-02-15 (+379d) |  |  |
| 22 | Conduct connectivity risk analysis | 2005-02-02 → 2006-02-16 (+379d) | 2005-02-02 → 2006-02-16 (+379d) |  |  |
| 23 | Connectivity requirements complete | 2005-02-02 → 2006-02-16 (+379d) | 2005-02-02 → 2006-02-16 (+379d) |  |  |
| 24 | **Partner Prescribing Module Requirements** | 2005-01-24 → 2006-02-07 (+379d) | 2005-02-10 → 2006-02-24 (+379d) |  |  |
| 25 | Document app, general | 2005-01-24 → 2006-02-07 (+379d) | 2005-01-24 → 2006-02-07 (+379d) |  |  |
| 26 | Document current workflow | 2005-01-25 → 2006-02-08 (+379d) | 2005-01-27 → 2006-02-10 (+379d) |  |  |
| 27 | Document admin flow | 2005-01-28 → 2006-02-13 (+381d) | 2005-01-28 → 2006-02-13 (+381d) |  |  |
| 28 | Identify problem areas | 2005-01-31 → 2006-02-14 (+379d) | 2005-01-31 → 2006-02-14 (+379d) |  |  |
| 29 | Identify patient attributes | 2005-02-01 → 2006-02-15 (+379d) | 2005-02-01 → 2006-02-15 (+379d) |  |  |
| 30 | Identify prescriber attributes | 2005-02-02 → 2006-02-16 (+379d) | 2005-02-02 → 2006-02-16 (+379d) |  |  |
| 31 | Identify pharmacy attributes | 2005-02-03 → 2006-02-17 (+379d) | 2005-02-03 → 2006-02-17 (+379d) |  |  |
| 32 | Update solution document | 2005-02-04 → 2006-02-20 (+381d) | 2005-02-07 → 2006-02-21 (+379d) |  |  |
| 33 | Document versions & release plan | 2005-02-08 → 2006-02-22 (+379d) | 2005-02-10 → 2006-02-24 (+379d) |  |  |
| 34 | Prescribing module requirements & analysis complete | 2005-02-10 → 2006-02-24 (+379d) | 2005-02-10 → 2006-02-24 (+379d) |  |  |
| 35 | **Partner SCRIPT Interface Requirements** | 2005-02-11 → 2006-02-27 (+381d) | 2005-02-24 → 2006-03-10 (+379d) |  |  |
| 36 | Example scenarios review | 2005-02-11 → 2006-02-27 (+381d) | 2005-02-15 → 2006-03-01 (+379d) |  |  |
| 37 | Implementation guide review | 2005-02-11 → 2006-02-27 (+381d) | 2005-02-15 → 2006-03-01 (+379d) |  |  |
| 38 | Implementation requirements review | 2005-02-11 → 2006-02-27 (+381d) | 2005-02-15 → 2006-03-01 (+379d) |  |  |
| 39 | Document messaging attributes | 2005-02-16 → 2006-03-02 (+379d) | 2005-02-16 → 2006-03-02 (+379d) |  |  |
| 40 | Document intended workflow | 2005-02-17 → 2006-03-03 (+379d) | 2005-02-18 → 2006-03-06 (+381d) |  |  |
| 41 | Gap analysis for modified messaging flow | 2005-02-21 → 2006-03-07 (+379d) | 2005-02-22 → 2006-03-08 (+379d) |  |  |
| 42 | Update solution document | 2005-02-23 → 2006-03-09 (+379d) | 2005-02-24 → 2006-03-10 (+379d) |  |  |
| 43 | SCRIPT interface requirements complete | 2005-02-24 → 2006-03-10 (+379d) | 2005-02-24 → 2006-03-10 (+379d) |  |  |
| 44 | **Directory Interface Requirements** | 2005-01-24 → 2006-02-07 (+379d) | 2005-01-27 → 2006-02-10 (+379d) |  |  |
| 45 | SPI mapping requirements | 2005-01-24 → 2006-02-07 (+379d) | 2005-01-25 → 2006-02-08 (+379d) |  |  |
| 46 | NCPDP mapping requirements | 2005-01-24 → 2006-02-07 (+379d) | 2005-01-25 → 2006-02-08 (+379d) |  |  |
| 47 | Service level requirements | 2005-01-24 → 2006-02-07 (+379d) | 2005-01-25 → 2006-02-08 (+379d) |  |  |
| 48 | Update solution document | 2005-01-26 → 2006-02-09 (+379d) | 2005-01-27 → 2006-02-10 (+379d) |  |  |
| 49 | Directory interface requirements complete | 2005-01-27 → 2006-02-10 (+379d) | 2005-01-27 → 2006-02-10 (+379d) |  |  |
| 50 | **Design Phase** | 2005-02-03 → 2006-02-17 (+379d) | 2005-03-15 → 2006-03-29 (+379d) |  |  |
| 51 | **Connectivity Design** | 2005-02-03 → 2006-02-17 (+379d) | 2005-02-16 → 2006-03-02 (+379d) |  |  |
| 52 | Document proposed connectivity | 2005-02-03 → 2006-02-17 (+379d) | 2005-02-03 → 2006-02-17 (+379d) |  |  |
| 53 | Connectivity design approved by network | 2005-02-04 → 2006-02-20 (+381d) | 2005-02-07 → 2006-02-21 (+379d) |  |  |
| 54 | Connectivity design approved by security | 2005-02-08 → 2006-02-22 (+379d) | 2005-02-10 → 2006-02-24 (+379d) |  |  |
| 55 | Connectivity design approved by SureScripts/hoster | 2005-02-11 → 2006-02-27 (+381d) | 2005-02-15 → 2006-03-01 (+379d) |  |  |
| 56 | Update solution document | 2005-02-16 → 2006-03-02 (+379d) | 2005-02-16 → 2006-03-02 (+379d) |  |  |
| 57 | Connectivity design complete | 2005-02-16 → 2006-03-02 (+379d) | 2005-02-16 → 2006-03-02 (+379d) |  |  |
| 58 | **Partner Prescribing Module Design** | 2005-02-11 → 2006-02-27 (+381d) | 2005-03-07 → 2006-03-21 (+379d) |  |  |
| 59 | Create map, module data elements to SCRIPT data elements | 2005-02-11 → 2006-02-27 (+381d) | 2005-02-17 → 2006-03-03 (+379d) |  |  |
| 60 | Data element validation, size and value limitation | 2005-02-11 → 2006-02-27 (+381d) | 2005-02-17 → 2006-03-03 (+379d) |  |  |
| 61 | Patient identification algorithm | 2005-02-18 → 2006-03-06 (+381d) | 2005-02-22 → 2006-03-08 (+379d) |  |  |
| 62 | Prescriber identification algorithm | 2005-02-23 → 2006-03-09 (+379d) | 2005-02-25 → 2006-03-13 (+381d) |  |  |
| 63 | Pharmacy identification algorithm | 2005-02-28 → 2006-03-14 (+379d) | 2005-03-02 → 2006-03-16 (+379d) |  |  |
| 64 | Update solution document | 2005-03-03 → 2006-03-17 (+379d) | 2005-03-07 → 2006-03-21 (+379d) |  |  |
| 65 | Prescribing module design complete | 2005-03-07 → 2006-03-21 (+379d) | 2005-03-07 → 2006-03-21 (+379d) |  |  |
| 66 | **Partner SCRIPT Interface Design** | 2005-02-25 → 2006-03-13 (+381d) | 2005-03-15 → 2006-03-29 (+379d) |  |  |
| 67 | Transport design | 2005-02-25 → 2006-03-13 (+381d) | 2005-03-01 → 2006-03-15 (+379d) |  |  |
| 68 | Message format/content design (and portal) | 2005-03-02 → 2006-03-16 (+379d) | 2005-03-09 → 2006-03-23 (+379d) |  |  |
| 69 | Workflow design | 2005-03-10 → 2006-03-24 (+379d) | 2005-03-14 → 2006-03-28 (+379d) |  |  |
| 70 | Update solution document | 2005-03-15 → 2006-03-29 (+379d) | 2005-03-15 → 2006-03-29 (+379d) |  |  |

| ID | Task | Start | Finish | Duration | Other |
| --- | --- | --- | --- | --- | --- |
| 71 | SCRIPT interface design complete | 2005-03-15 → 2006-03-29 (+379d) | 2005-03-15 → 2006-03-29 (+379d) |  |  |
| 72 | **Directory Interface Design** | 2005-02-03 → 2006-02-17 (+379d) | 2005-02-16 → 2006-03-02 (+379d) |  |  |
| 73 | SPI mapping design | 2005-02-03 → 2006-02-17 (+379d) | 2005-02-07 → 2006-02-21 (+379d) |  |  |
| 74 | NCPDP mapping design | 2005-02-08 → 2006-02-22 (+379d) | 2005-02-09 → 2006-02-23 (+379d) |  |  |
| 75 | Service level design | 2005-02-10 → 2006-02-24 (+379d) | 2005-02-11 → 2006-02-27 (+381d) |  |  |
| 76 | Web service methods TBI by partner | 2005-02-14 → 2006-02-28 (+379d) | 2005-02-15 → 2006-03-01 (+379d) |  |  |
| 77 | Update solution document | 2005-02-16 → 2006-03-02 (+379d) | 2005-02-16 → 2006-03-02 (+379d) |  |  |
| 78 | Directory interface design complete | 2005-02-16 → 2006-03-02 (+379d) | 2005-02-16 → 2006-03-02 (+379d) |  |  |
| 79 | **Build Phase** | 2005-02-17 → 2006-03-03 (+379d) | 2005-05-03 → 2006-05-17 (+379d) |  |  |
| 80 | Create partner account, Staging | 2005-02-17 → 2006-03-03 (+379d) | 2005-02-17 → 2006-03-03 (+379d) |  |  |
| 81 | Identify/add dev/test users for Admin Console access | 2005-02-17 → 2006-03-03 (+379d) | 2005-02-17 → 2006-03-03 (+379d) |  |  |
| 82 | **Connectivity Build** | 2005-02-17 → 2006-03-03 (+379d) | 2005-02-23 → 2006-03-09 (+379d) |  |  |
| 83 | Staging firewall change | 2005-02-17 → 2006-03-03 (+379d) | 2005-02-23 → 2006-03-09 (+379d) |  |  |
| 84 | Staging encryption setup | 2005-02-17 → 2006-03-03 (+379d) | 2005-02-18 → 2006-03-06 (+381d) |  |  |
| 85 | Production firewall change, admin console | 2005-02-17 → 2006-03-03 (+379d) | 2005-02-23 → 2006-03-09 (+379d) |  |  |
| 86 | Production firewall change, messaging | 2005-02-17 → 2006-03-03 (+379d) | 2005-02-23 → 2006-03-09 (+379d) |  |  |
| 87 | Production encryption setup | 2005-02-17 → 2006-03-03 (+379d) | 2005-02-18 → 2006-03-06 (+381d) |  |  |
| 88 | Update solution document | 2005-02-17 → 2006-03-03 (+379d) | 2005-02-17 → 2006-03-03 (+379d) |  |  |
| 89 | Connectivity build complete | 2005-02-23 → 2006-03-09 (+379d) | 2005-02-23 → 2006-03-09 (+379d) |  |  |
| 90 | Admin Console, User Training | 2005-02-24 → 2006-03-10 (+379d) | 2005-02-24 → 2006-03-10 (+379d) |  |  |
| 91 | **Partner Prescribing Module Build** | 2005-03-16 → 2006-03-30 (+379d) | 2005-04-08 → 2006-04-24 (+381d) |  |  |
| 92 | DEA Scheduled drug, route to print or fax | 2005-03-16 → 2006-03-30 (+379d) | 2005-03-18 → 2006-04-03 (+381d) |  | was named Scheduled drug, route to print or fax |
| 93 | NEWRX creation | 2005-03-21 → 2006-04-04 (+379d) | 2005-03-23 → 2006-04-06 (+379d) |  |  |
| 94 | REFREQ approved, quantity change | 2005-03-24 → 2006-04-07 (+379d) | 2005-03-25 → 2006-04-10 (+381d) |  |  |
| 95 | REFREQ denied, NEWRX to follow | 2005-03-28 → 2006-04-11 (+379d) | 2005-03-31 → 2006-04-14 (+379d) |  |  |
| 96 | Add new user dataflow to web service client | 2005-04-01 → 2006-04-17 (+381d) | 2005-04-06 → 2006-04-20 (+379d) |  |  |
| 97 | Update solution document | 2005-04-07 → 2006-04-21 (+379d) | 2005-04-08 → 2006-04-24 (+381d) |  |  |
| 98 | Prescribing module build complete | 2005-04-08 → 2006-04-24 (+381d) | 2005-04-08 → 2006-04-24 (+381d) |  |  |
| 99 | **Partner SCRIPT Interface Build** | 2005-03-16 → 2006-03-30 (+379d) | 2005-05-03 → 2006-05-17 (+379d) |  |  |
| 100 | Server dev | 2005-03-16 → 2006-03-30 (+379d) | 2005-03-22 → 2006-04-05 (+379d) |  |  |
| 101 | Client dev | 2005-03-23 → 2006-04-06 (+379d) | 2005-03-25 → 2006-04-10 (+381d) |  |  |
| 102 | STATUS/ERROR dev | 2005-03-28 → 2006-04-11 (+379d) | 2005-03-29 → 2006-04-12 (+379d) |  |  |
| 103 | NEWRX dev | 2005-03-30 → 2006-04-13 (+379d) | 2005-04-07 → 2006-04-21 (+379d) |  |  |
| 104 | REFREQ dev | 2005-04-08 → 2006-04-24 (+381d) | 2005-04-18 → 2006-05-02 (+379d) |  |  |
| 105 | REFRES dev | 2005-04-19 → 2006-05-03 (+379d) | 2005-04-27 → 2006-05-11 (+379d) |  |  |
| 106 | VERIFY dev | 2005-04-28 → 2006-05-12 (+379d) | 2005-05-02 → 2006-05-16 (+379d) |  |  |
| 107 | Update solution document | 2005-05-03 → 2006-05-17 (+379d) | 2005-05-03 → 2006-05-17 (+379d) |  |  |
| 108 | SCRIPT interface build complete | 2005-05-03 → 2006-05-17 (+379d) | 2005-05-03 → 2006-05-17 (+379d) |  |  |
| 109 | **Directory Interface Build** | 2005-02-17 → 2006-03-03 (+379d) | 2005-03-09 → 2006-03-23 (+379d) |  |  |
| 110 | Web service client dev | 2005-02-17 → 2006-03-03 (+379d) | 2005-02-18 → 2006-03-06 (+381d) |  |  |
| 111 | Download file dev | 2005-02-21 → 2006-03-07 (+379d) | 2005-02-22 → 2006-03-08 (+379d) |  |  |
| 112 | Import download data to system dev | 2005-02-23 → 2006-03-09 (+379d) | 2005-02-25 → 2006-03-13 (+381d) |  |  |
| 113 | Reconcile download data to system dev | 2005-02-28 → 2006-03-14 (+379d) | 2005-03-08 → 2006-03-22 (+379d) |  |  |
| 114 | SPI lookup dev | 2005-02-17 → 2006-03-03 (+379d) | 2005-02-17 → 2006-03-03 (+379d) |  |  |
| 115 | NCPDP lookup dev | 2005-02-17 → 2006-03-03 (+379d) | 2005-02-17 → 2006-03-03 (+379d) |  |  |
| 116 | SPI/NCPDP validation dev | 2005-02-18 → 2006-03-06 (+381d) | 2005-02-21 → 2006-03-07 (+379d) |  |  |
| 117 | Service level lookup dev | 2005-02-22 → 2006-03-08 (+379d) | 2005-02-23 → 2006-03-09 (+379d) |  |  |
| 118 | Service level validation dev | 2005-02-24 → 2006-03-10 (+379d) | 2005-02-25 → 2006-03-13 (+381d) |  |  |
| 119 | Web service add/update methods | 2005-02-21 → 2006-03-07 (+379d) | 2005-02-25 → 2006-03-13 (+381d) |  |  |
| 120 | Update solution document | 2005-03-09 → 2006-03-23 (+379d) | 2005-03-09 → 2006-03-23 (+379d) |  |  |
| 121 | Directory interface build complete | 2005-03-09 → 2006-03-23 (+379d) | 2005-03-09 → 2006-03-23 (+379d) |  |  |
| 122 | **Test Phase** | 2005-01-10 → 2006-03-10 (+424d) | 2005-06-01 → 2006-06-15 (+379d) | 102d → 70d |  |
| 123 | **Connectivity Test** | 2005-02-24 → 2006-03-10 (+379d) | 2005-02-28 → 2006-03-14 (+379d) |  |  |
| 124 | Staging firewall connectivity | 2005-02-24 → 2006-03-10 (+379d) | 2005-02-24 → 2006-03-10 (+379d) |  |  |
| 125 | Staging application connectivity | 2005-02-24 → 2006-03-10 (+379d) | 2005-02-24 → 2006-03-10 (+379d) |  |  |
| 126 | Staging connectivity, application encryption | 2005-02-24 → 2006-03-10 (+379d) | 2005-02-24 → 2006-03-10 (+379d) |  |  |
| 127 | Staging connectivity, network encryption | 2005-02-24 → 2006-03-10 (+379d) | 2005-02-28 → 2006-03-14 (+379d) |  |  |
| 128 | Staging connectivity testing complete | 2005-02-28 → 2006-03-14 (+379d) | 2005-02-28 → 2006-03-14 (+379d) |  |  |
| 129 | Production firewall connectivity | 2005-02-24 → 2006-03-10 (+379d) | 2005-02-24 → 2006-03-10 (+379d) |  |  |
| 130 | Production application connectivity | 2005-02-24 → 2006-03-10 (+379d) | 2005-02-24 → 2006-03-10 (+379d) |  |  |
| 131 | Production connectivity, application encryption | 2005-02-24 → 2006-03-10 (+379d) | 2005-02-24 → 2006-03-10 (+379d) |  |  |
| 132 | Production connectivity, network encryption | 2005-02-24 → 2006-03-10 (+379d) | 2005-02-28 → 2006-03-14 (+379d) |  |  |
| 133 | Production connectivity testing complete | 2005-02-28 → 2006-03-14 (+379d) | 2005-02-28 → 2006-03-14 (+379d) |  |  |
| 134 | **Partner SCRIPT Interface Test** | 2005-05-04 → 2006-05-18 (+379d) | 2005-05-12 → 2006-05-26 (+379d) |  |  |
| 135 | Partner system testing | 2005-05-04 → 2006-05-18 (+379d) | 2005-05-12 → 2006-05-26 (+379d) |  |  |
| 136 | SCRIPT interface testing complete | 2005-05-12 → 2006-05-26 (+379d) | 2005-05-12 → 2006-05-26 (+379d) |  |  |
| 137 | **Directory Interface Test** | 2005-03-10 → 2006-03-24 (+379d) | 2005-03-21 → 2006-04-04 (+379d) |  |  |
| 138 | Download file to partner system | 2005-03-10 → 2006-03-24 (+379d) | 2005-03-10 → 2006-03-24 (+379d) |  |  |
| 139 | Import download data to partner system | 2005-03-11 → 2006-03-27 (+381d) | 2005-03-14 → 2006-03-28 (+379d) |  |  |
| 140 | Download data reconciled successfully | 2005-03-15 → 2006-03-29 (+379d) | 2005-03-16 → 2006-03-30 (+379d) |  |  |

| ID | Task | Start | Finish | Total float | Predecessors | Other |
| --- | --- | --- | --- | --- | --- | --- |
| 141 | Web service add/update entries successfully | 2005-03-17 → 2006-03-31 (+379d) | 2005-03-17 → 2006-03-31 (+379d) |  |  |  |
| 142 | Admin module add/update user successfully | 2005-03-18 → 2006-04-03 (+381d) | 2005-03-21 → 2006-04-04 (+379d) |  |  |  |
| 143 | Directory interface testing complete | 2005-03-21 → 2006-04-04 (+379d) | 2005-03-21 → 2006-04-04 (+379d) |  |  |  |
| 144 | Pre-Certification testing complete | 2005-05-12 → 2006-05-26 (+379d) | 2005-05-12 → 2006-05-26 (+379d) |  |  |  |
| 145 | OLA Executed | 2005-01-10 → 2006-05-26 (+501d) | 2005-01-10 → 2006-05-26 (+501d) | 88d → 0d | 6 → 144 | was named Operating Level Agreement Executed |
| 146 | **Certification** | 2005-05-13 → 2006-05-29 (+381d) | 2005-06-01 → 2006-06-15 (+379d) |  | 145, 144 → none |  |
| 147 | Detailed message review, element use | 2005-05-13 → 2006-05-29 (+381d) | 2005-05-16 → 2006-05-30 (+379d) |  | none → 145 |  |
| 148 | Detailed workflow review, screenshots | 2005-05-13 → 2006-05-29 (+381d) | 2005-05-16 → 2006-05-30 (+379d) |  | none → 145 |  |
| 149 | Config test platform for partner certification | 2005-05-13 → 2006-05-29 (+381d) | 2005-05-13 → 2006-05-29 (+381d) |  | none → 145 |  |
| 150 | NEWRX tests | 2005-05-17 → 2006-05-31 (+379d) | 2005-05-18 → 2006-06-01 (+379d) |  |  |  |
| 151 | REFREQ tests | 2005-05-19 → 2006-06-02 (+379d) | 2005-05-20 → 2006-06-05 (+381d) |  |  |  |
| 152 | REFRES tests | 2005-05-23 → 2006-06-06 (+379d) | 2005-05-24 → 2006-06-07 (+379d) |  |  |  |
| 153 | Scheduled drug test | 2005-05-25 → 2006-06-08 (+379d) | 2005-05-25 → 2006-06-08 (+379d) |  |  |  |
| 154 | Free standing ERROR test | 2005-05-26 → 2006-06-09 (+379d) | 2005-05-26 → 2006-06-09 (+379d) |  |  |  |
| 155 | Failover test, to fax | 2005-05-27 → 2006-06-12 (+381d) | 2005-05-27 → 2006-06-12 (+381d) |  |  |  |
| 156 | Directory web services tests | 2005-05-30 → 2006-06-13 (+379d) | 2005-05-30 → 2006-06-13 (+379d) |  |  |  |
| 157 | Final review of all messages and screenshots | 2005-05-31 → 2006-06-14 (+379d) | 2005-06-01 → 2006-06-15 (+379d) |  |  |  |
| 158 | Partner questionnaire to SureScripts | 2005-05-25 → 2006-06-08 (+379d) | 2005-05-25 → 2006-06-08 (+379d) |  |  |  |
| 159 | Certification complete | 2005-06-01 → 2006-06-15 (+379d) | 2005-06-01 → 2006-06-15 (+379d) |  |  |  |
| 160 | **Production Readiness Phase** | 2005-06-02 → 2006-06-16 (+379d) | 2005-06-13 → 2006-06-27 (+379d) |  |  |  |
| 161 | **Setup** | 2005-06-02 → 2006-06-16 (+379d) | 2005-06-10 → 2006-06-26 (+381d) |  |  |  |
| 162 | Partner SCRIPT interface production deployment | 2005-06-02 → 2006-06-16 (+379d) | 2005-06-06 → 2006-06-20 (+379d) |  |  |  |
| 163 | Partner directory interface production deployment | 2005-06-07 → 2006-06-21 (+379d) | 2005-06-07 → 2006-06-21 (+379d) |  |  |  |
| 164 | SureScripts messaging, server setup | 2005-06-08 → 2006-06-22 (+379d) | 2005-06-08 → 2006-06-22 (+379d) |  |  |  |
| 165 | Identify/add support users for Admin Console access | 2005-06-09 → 2006-06-23 (+379d) | 2005-06-09 → 2006-06-23 (+379d) |  |  |  |
| 166 | Initial partner directory data loaded | 2005-06-09 → 2006-06-23 (+379d) | 2005-06-09 → 2006-06-23 (+379d) |  |  |  |
| 167 | Reconfirm network connectivity | 2005-06-10 → 2006-06-26 (+381d) | 2005-06-10 → 2006-06-26 (+381d) |  |  |  |
| 168 | Production setup complete | 2005-06-10 → 2006-06-26 (+381d) | 2005-06-10 → 2006-06-26 (+381d) |  |  |  |
| 169 | **Support** | 2005-06-02 → 2006-06-16 (+379d) | 2005-06-13 → 2006-06-27 (+379d) |  |  |  |
| 170 | Admin Console, User Training | 2005-06-10 → 2006-06-26 (+381d) | 2005-06-10 → 2006-06-26 (+381d) |  |  |  |
| 171 | Brief partner on SureScripts support services | 2005-06-13 → 2006-06-27 (+379d) | 2005-06-13 → 2006-06-27 (+379d) |  |  |  |
| 172 | All partner support email/contacts received | 2005-06-02 → 2006-06-16 (+379d) | 2005-06-03 → 2006-06-19 (+381d) |  |  |  |
| 173 | All partner support escalation contacts received | 2005-06-02 → 2006-06-16 (+379d) | 2005-06-03 → 2006-06-19 (+381d) |  |  |  |
| 174 | All partner support contacts added to SureScripts Support System | 2005-06-06 → 2006-06-20 (+379d) | 2005-06-06 → 2006-06-20 (+379d) |  |  |  |
| 175 | Implementation Closeout Meeting | 2005-06-13 → 2006-06-27 (+379d) | 2005-06-13 → 2006-06-27 (+379d) |  |  |  |

## Version 4 (data date 2006-02-02, saved 2006-02-02, file SureScripts_Medent_Imp_Updated.mpp)

Last finish 2006-06-27 → 2006-05-11 (-47d). Complete tasks 0 → 8.

Changed:

| ID | Task | Start | Finish | Duration | Complete | Total float |
| --- | --- | --- | --- | --- | --- | --- |
| 1 | **Medent- SureScripts Implementation Project** | 2006-01-17 A | 2006-06-27 → 2006-05-11 (-47d) | 116d → 83d? | 0% → 7% |  |
| 2 | **Initiation Phase** | 2006-01-17 A | 2006-02-06 A |  | 0% → 100% | 0d → none |
| 3 | NDA executed | 2006-01-17 A | 2006-01-23 A |  | 0% → 100% | 0d → none |
| 4 | Deliver implementation documentation | 2006-01-24 A | 2006-01-24 A |  | 0% → 100% | 0d → none |
| 5 | Contract ratified | 2006-01-24 A | 2006-01-24 A |  | 0% → 100% | 0d → none |
| 6 | Deliver OLA | 2006-01-24 A | 2006-01-24 A |  | 0% → 100% | 0d → none |
| 7 | **Project Planning** | 2006-01-25 A | 2006-02-06 A |  | 0% → 100% | 0d → none |
| 8 | Revise implementation template | 2006-01-25 A | 2006-01-31 A |  | 0% → 100% | 0d → none |
| 9 | Distribute for comment | 2006-02-01 A | 2006-02-01 A |  | 0% → 100% | 0d → none |
| 10 | Review/modify plan | 2006-02-02 A | 2006-02-06 A |  | 0% → 100% | 0d → none |
| 11 | Implementation plan complete | 2006-02-06 A | 2006-02-06 A |  | 0% → 100% | 0d → none |
| 12 | **Requirements & Analysis Phase** |  | 2006-03-10 → 2006-02-23 (-15d) | 24d → 13d |  |  |
| 14 | **Connectivity Requirements** |  | 2006-02-16 → 2006-02-10 (-6d) | 8d → 4d |  | 16d → 7d |
| 15 | Define environments |  | 2006-02-09 → 2006-02-07 (-2d) | 3d → 1d |  | 98d → 67d |
| 16 | Assess aggregator requirements |  | 2006-02-09 → 2006-02-07 (-2d) | 3d → 1d |  | 98d → 67d |
| 17 | Assess connectivity mgmt |  | 2006-02-09 → 2006-02-07 (-2d) | 3d → 1d |  | 98d → 67d |
| 18 | Assess DNS requirements |  | 2006-02-09 → 2006-02-07 (-2d) | 3d → 1d |  | 98d → 67d |
| 19 | Assess throughput requirements |  | 2006-02-09 → 2006-02-07 (-2d) | 3d → 1d |  | 16d → 7d |
| 20 | Assess environment requirements/impact | 2006-02-10 → 2006-02-08 (-2d) | 2006-02-13 → 2006-02-08 (-5d) | 2d → 1d |  | 16d → 7d |
| 21 | Update solution document w/requirements & assumptions | 2006-02-14 → 2006-02-09 (-5d) | 2006-02-15 → 2006-02-09 (-6d) | 2d → 1d |  | 16d → 7d |
| 22 | Conduct connectivity risk analysis | 2006-02-16 → 2006-02-10 (-6d) | 2006-02-16 → 2006-02-10 (-6d) |  |  | 16d → 7d |
| 23 | Connectivity requirements complete | 2006-02-16 → 2006-02-10 (-6d) | 2006-02-16 → 2006-02-10 (-6d) |  |  | 16d → 7d |
| 24 | **Partner Prescribing Module Requirements** |  | 2006-02-24 → 2006-02-16 (-8d) | 14d → 8d |  |  |
| 26 | Document current workflow |  | 2006-02-10 → 2006-02-08 (-2d) | 3d → 1d |  |  |
| 27 | Document admin flow | 2006-02-13 → 2006-02-09 (-4d) | 2006-02-13 → 2006-02-09 (-4d) |  |  |  |
| 28 | Identify problem areas | 2006-02-14 → 2006-02-10 (-4d) | 2006-02-14 → 2006-02-10 (-4d) |  |  |  |
| 29 | Identify patient attributes | 2006-02-15 → 2006-02-13 (-2d) | 2006-02-15 → 2006-02-13 (-2d) |  |  |  |
| 30 | Identify prescriber attributes | 2006-02-16 → 2006-02-14 (-2d) | 2006-02-16 → 2006-02-14 (-2d) |  |  |  |
| 31 | Identify pharmacy attributes | 2006-02-17 → 2006-02-15 (-2d) | 2006-02-17 → 2006-02-15 (-2d) |  |  |  |
| 32 | Update solution document | 2006-02-20 → 2006-02-16 (-4d) | 2006-02-21 → 2006-02-16 (-5d) | 2d → 1d |  |  |
| 33 | Document versions & release plan | 2006-02-22 → 2006-02-16 (-6d) | 2006-02-24 → 2006-02-16 (-8d) | 3d → 0d |  |  |
| 34 | Prescribing module requirements & analysis complete | 2006-02-24 → 2006-02-16 (-8d) | 2006-02-24 → 2006-02-16 (-8d) |  |  |  |
| 35 | **Partner SCRIPT Interface Requirements** | 2006-02-27 → 2006-02-17 (-10d) | 2006-03-10 → 2006-02-23 (-15d) | 10d → 5d |  |  |
| 36 | Example scenarios review | 2006-02-27 → 2006-02-17 (-10d) | 2006-03-01 → 2006-02-17 (-12d) | 3d → 1d |  | 84d → 59d |
| 37 | Implementation guide review | 2006-02-27 → 2006-02-17 (-10d) | 2006-03-01 → 2006-02-17 (-12d) | 3d → 1d |  | 84d → 59d |
| 38 | Implementation requirements review | 2006-02-27 → 2006-02-17 (-10d) | 2006-03-01 → 2006-02-17 (-12d) | 3d → 1d |  |  |
| 39 | Document messaging attributes | 2006-03-02 → 2006-02-20 (-10d) | 2006-03-02 → 2006-02-20 (-10d) |  |  |  |
| 40 | Document intended workflow | 2006-03-03 → 2006-02-21 (-10d) | 2006-03-06 → 2006-02-21 (-13d) | 2d → 1d |  |  |
| 41 | Gap analysis for modified messaging flow | 2006-03-07 → 2006-02-22 (-13d) | 2006-03-08 → 2006-02-22 (-14d) | 2d → 1d |  |  |
| 42 | Update solution document | 2006-03-09 → 2006-02-23 (-14d) | 2006-03-10 → 2006-02-23 (-15d) | 2d → 1d |  |  |
| 43 | SCRIPT interface requirements complete | 2006-03-10 → 2006-02-23 (-15d) | 2006-03-10 → 2006-02-23 (-15d) |  |  |  |
| 50 | **Design Phase** | 2006-02-17 → 2006-02-13 (-4d) | 2006-03-29 → 2006-03-07 (-22d) | 29d → 17d? |  | 16d → 7d |
| 51 | **Connectivity Design** | 2006-02-17 → 2006-02-13 (-4d) | 2006-03-02 → 2006-02-24 (-6d) |  |  | 19d → 7d |
| 52 | Document proposed connectivity | 2006-02-17 → 2006-02-13 (-4d) | 2006-02-17 → 2006-02-13 (-4d) |  |  | 19d → 7d |
| 53 | Connectivity design approved by network | 2006-02-20 → 2006-02-14 (-6d) | 2006-02-21 → 2006-02-15 (-6d) |  |  | 19d → 7d |
| 54 | Connectivity design approved by security | 2006-02-22 → 2006-02-16 (-6d) | 2006-02-24 → 2006-02-20 (-4d) |  |  | 19d → 7d |
| 55 | Connectivity design approved by SureScripts/hoster | 2006-02-27 → 2006-02-21 (-6d) | 2006-03-01 → 2006-02-23 (-6d) |  |  | 19d → 7d |
| 56 | Update solution document | 2006-03-02 → 2006-02-24 (-6d) | 2006-03-02 → 2006-02-24 (-6d) |  |  | 19d → 7d |
| 57 | Connectivity design complete | 2006-03-02 → 2006-02-24 (-6d) | 2006-03-02 → 2006-02-24 (-6d) |  |  | 19d → 7d |
| 58 | **Partner Prescribing Module Design** | 2006-02-27 → 2006-02-17 (-10d) | 2006-03-21 → 2006-02-27 (-22d) | 17d → 7d |  | 52d → 41d |
| 59 | Create map, module data elements to SCRIPT data elements | 2006-02-27 → 2006-02-17 (-10d) | 2006-03-03 → 2006-02-20 (-11d) | 5d → 2d |  | 82d → 58d |
| 60 | Data element validation, size and value limitation | 2006-02-27 → 2006-02-17 (-10d) | 2006-03-03 → 2006-02-20 (-11d) | 5d → 2d |  | 52d → 41d |
| 61 | Patient identification algorithm | 2006-03-06 → 2006-02-21 (-13d) | 2006-03-08 → 2006-02-21 (-15d) | 3d → 1d |  | 52d → 41d |
| 62 | Prescriber identification algorithm | 2006-03-09 → 2006-02-22 (-15d) | 2006-03-13 → 2006-02-22 (-19d) | 3d → 1d |  | 52d → 41d |
| 63 | Pharmacy identification algorithm | 2006-03-14 → 2006-02-23 (-19d) | 2006-03-16 → 2006-02-24 (-20d) | 3d → 2d |  | 52d → 41d |
| 64 | Update solution document | 2006-03-17 → 2006-02-27 (-18d) | 2006-03-21 → 2006-02-27 (-22d) | 3d → 1d |  | 52d → 41d |
| 65 | Prescribing module design complete | 2006-03-21 → 2006-02-27 (-22d) | 2006-03-21 → 2006-02-27 (-22d) |  |  | 52d → 41d |
| 66 | **Partner SCRIPT Interface Design** | 2006-03-13 → 2006-02-24 (-17d) | 2006-03-29 → 2006-03-07 (-22d) | 13d → 8d |  |  |
| 67 | Transport design | 2006-03-13 → 2006-02-24 (-17d) | 2006-03-15 → 2006-02-24 (-19d) | 3d → 1d |  |  |
| 68 | Message format/content design (and portal) | 2006-03-16 → 2006-02-27 (-17d) | 2006-03-23 → 2006-03-02 (-21d) | 6d → 4d |  |  |
| 69 | Workflow design | 2006-03-24 → 2006-03-03 (-21d) | 2006-03-28 → 2006-03-06 (-22d) | 3d → 2d |  |  |
| 70 | Update solution document | 2006-03-29 → 2006-03-07 (-22d) | 2006-03-29 → 2006-03-07 (-22d) |  |  |  |
| 71 | SCRIPT interface design complete | 2006-03-29 → 2006-03-07 (-22d) | 2006-03-29 → 2006-03-07 (-22d) |  |  |  |
| 72 | **Directory Interface Design** | 2006-02-17 → 2006-02-13 (-4d) | 2006-03-02 → 2006-02-20 (-10d) | 10d → 6d? |  | 38d → 20d |
| 73 | SPI mapping design | 2006-02-17 → 2006-02-13 (-4d) | 2006-02-21 → 2006-02-14 (-7d) | 3d → 2d |  | 38d → 20d |
| 74 | NCPDP mapping design | 2006-02-22 → 2006-02-15 (-7d) | 2006-02-23 → 2006-02-15 (-8d) | 2d → 1d |  | 38d → 20d |
| 75 | Service level design | 2006-02-24 → 2006-02-16 (-8d) | 2006-02-27 → 2006-02-16 (-11d) | 2d → 1d |  | 38d → 20d |
| 76 | Web service methods TBI by partner | 2006-02-28 → 2006-02-17 (-11d) | 2006-03-01 → 2006-02-17 (-12d) | 2d → 1d? |  | 38d → 20d |
| 77 | Update solution document | 2006-03-02 → 2006-02-20 (-10d) | 2006-03-02 → 2006-02-20 (-10d) |  |  | 38d → 20d |
| 78 | Directory interface design complete | 2006-03-02 → 2006-02-20 (-10d) | 2006-03-02 → 2006-02-20 (-10d) |  |  | 38d → 20d |

| ID | Task | Start | Finish | Duration | Total float |
| --- | --- | --- | --- | --- | --- |
| 79 | **Build Phase** | 2006-03-03 → 2006-02-27 (-4d) | 2006-05-17 → 2006-04-05 (-42d) | 54d → 28d | 19d → 7d |
| 80 | Create partner account, Staging | 2006-03-03 → 2006-02-27 (-4d) | 2006-03-03 → 2006-02-27 (-4d) |  | 82d → 53d |
| 81 | Identify/add dev/test users for Admin Console access | 2006-03-03 → 2006-02-27 (-4d) | 2006-03-03 → 2006-02-27 (-4d) |  | 82d → 53d |
| 82 | **Connectivity Build** | 2006-03-03 → 2006-02-27 (-4d) | 2006-03-09 → 2006-03-01 (-8d) | 5d → 3d | 46d → 23d |
| 83 | Staging firewall change | 2006-03-03 → 2006-02-27 (-4d) | 2006-03-09 → 2006-03-01 (-8d) | 5d → 3d | 77d → 50d |
| 84 | Staging encryption setup | 2006-03-03 → 2006-02-27 (-4d) | 2006-03-06 → 2006-02-28 (-6d) |  | 81d → 52d |
| 85 | Production firewall change, admin console | 2006-03-03 → 2006-02-27 (-4d) | 2006-03-09 → 2006-03-01 (-8d) | 5d → 3d | 78d → 51d |
| 86 | Production firewall change, messaging | 2006-03-03 → 2006-02-27 (-4d) | 2006-03-09 → 2006-03-01 (-8d) | 5d → 3d | 46d → 23d |
| 87 | Production encryption setup | 2006-03-03 → 2006-02-27 (-4d) | 2006-03-06 → 2006-02-28 (-6d) |  | 81d → 52d |
| 88 | Update solution document | 2006-03-03 → 2006-02-27 (-4d) | 2006-03-03 → 2006-02-27 (-4d) |  | 82d → 53d |
| 89 | Connectivity build complete | 2006-03-09 → 2006-03-01 (-8d) | 2006-03-09 → 2006-03-01 (-8d) |  | 46d → 23d |
| 90 | Admin Console, User Training | 2006-03-10 → 2006-03-02 (-8d) | 2006-03-10 → 2006-03-02 (-8d) |  | 77d → 50d |
| 91 | **Partner Prescribing Module Build** | 2006-03-30 → 2006-03-08 (-22d) | 2006-04-24 → 2006-03-23 (-32d) | 18d → 12d | 46d → 35d |
| 92 | DEA Scheduled drug, route to print or fax | 2006-03-30 → 2006-03-08 (-22d) | 2006-04-03 → 2006-03-08 (-26d) | 3d → 1d | 46d → 35d |
| 93 | NEWRX creation | 2006-04-04 → 2006-03-09 (-26d) | 2006-04-06 → 2006-03-10 (-27d) | 3d → 2d | 46d → 35d |
| 94 | REFREQ approved, quantity change | 2006-04-07 → 2006-03-13 (-25d) | 2006-04-10 → 2006-03-14 (-27d) |  | 46d → 35d |
| 95 | REFREQ denied, NEWRX to follow | 2006-04-11 → 2006-03-15 (-27d) | 2006-04-14 → 2006-03-17 (-28d) | 4d → 3d | 46d → 35d |
| 96 | Add new user dataflow to web service client | 2006-04-17 → 2006-03-20 (-28d) | 2006-04-20 → 2006-03-22 (-29d) | 4d → 3d | 46d → 35d |
| 97 | Update solution document | 2006-04-21 → 2006-03-23 (-29d) | 2006-04-24 → 2006-03-23 (-32d) | 2d → 1d | 46d → 35d |
| 98 | Prescribing module build complete | 2006-04-24 → 2006-03-23 (-32d) | 2006-04-24 → 2006-03-23 (-32d) |  | 46d → 35d |
| 99 | **Partner SCRIPT Interface Build** | 2006-03-30 → 2006-03-08 (-22d) | 2006-05-17 → 2006-04-05 (-42d) | 35d → 21d |  |
| 100 | Server dev | 2006-03-30 → 2006-03-08 (-22d) | 2006-04-05 → 2006-03-10 (-26d) | 5d → 3d |  |
| 101 | Client dev | 2006-04-06 → 2006-03-13 (-24d) | 2006-04-10 → 2006-03-14 (-27d) | 3d → 2d |  |
| 102 | STATUS/ERROR dev | 2006-04-11 → 2006-03-15 (-27d) | 2006-04-12 → 2006-03-15 (-28d) | 2d → 1d |  |
| 103 | NEWRX dev | 2006-04-13 → 2006-03-16 (-28d) | 2006-04-21 → 2006-03-21 (-31d) | 7d → 4d |  |
| 104 | REFREQ dev | 2006-04-24 → 2006-03-22 (-33d) | 2006-05-02 → 2006-03-27 (-36d) | 7d → 4d |  |
| 105 | REFRES dev | 2006-05-03 → 2006-03-28 (-36d) | 2006-05-11 → 2006-03-31 (-41d) | 7d → 4d |  |
| 106 | VERIFY dev | 2006-05-12 → 2006-04-03 (-39d) | 2006-05-16 → 2006-04-04 (-42d) | 3d → 2d |  |
| 107 | Update solution document | 2006-05-17 → 2006-04-05 (-42d) | 2006-05-17 → 2006-04-05 (-42d) |  |  |
| 108 | SCRIPT interface build complete | 2006-05-17 → 2006-04-05 (-42d) | 2006-05-17 → 2006-04-05 (-42d) |  |  |
| 109 | **Directory Interface Build** | 2006-03-03 → 2006-02-27 (-4d) | 2006-03-23 → 2006-03-13 (-10d) | 15d → 11d | 38d → 16d |
| 110 | Web service client dev | 2006-03-03 → 2006-02-27 (-4d) | 2006-03-06 → 2006-02-28 (-6d) |  | 38d → 16d |
| 111 | Download file dev | 2006-03-07 → 2006-03-01 (-6d) | 2006-03-08 → 2006-03-02 (-6d) |  | 38d → 16d |
| 112 | Import download data to system dev | 2006-03-09 → 2006-03-03 (-6d) | 2006-03-13 → 2006-03-06 (-7d) | 3d → 2d | 38d → 16d |
| 113 | Reconcile download data to system dev | 2006-03-14 → 2006-03-07 (-7d) | 2006-03-22 → 2006-03-10 (-12d) | 7d → 4d | 38d → 16d |
| 114 | SPI lookup dev | 2006-03-03 → 2006-02-27 (-4d) | 2006-03-03 → 2006-02-27 (-4d) |  | 82d → 53d |
| 115 | NCPDP lookup dev | 2006-03-03 → 2006-02-27 (-4d) | 2006-03-03 → 2006-02-27 (-4d) |  | 76d → 47d |
| 116 | SPI/NCPDP validation dev | 2006-03-06 → 2006-02-28 (-6d) | 2006-03-07 → 2006-03-01 (-6d) |  | 76d → 47d |
| 117 | Service level lookup dev | 2006-03-08 → 2006-03-02 (-6d) | 2006-03-09 → 2006-03-03 (-6d) |  | 76d → 47d |
| 118 | Service level validation dev | 2006-03-10 → 2006-03-06 (-4d) | 2006-03-13 → 2006-03-07 (-6d) |  | 76d → 47d |
| 119 | Web service add/update methods | 2006-03-07 → 2006-03-01 (-6d) | 2006-03-13 → 2006-03-03 (-10d) | 5d → 3d | 76d → 49d |
| 120 | Update solution document | 2006-03-23 → 2006-03-13 (-10d) | 2006-03-23 → 2006-03-13 (-10d) |  | 38d → 16d |
| 121 | Directory interface build complete | 2006-03-23 → 2006-03-13 (-10d) | 2006-03-23 → 2006-03-13 (-10d) |  | 38d → 16d |
| 122 | **Test Phase** | 2006-03-10 → 2006-03-02 (-8d) | 2006-06-15 → 2006-05-02 (-44d) | 70d → 44d | 8d → 7d |
| 123 | **Connectivity Test** | 2006-03-10 → 2006-03-02 (-8d) | 2006-03-14 → 2006-03-03 (-11d) | 3d → 2d | 46d → 23d |
| 124 | Staging firewall connectivity | 2006-03-10 → 2006-03-02 (-8d) | 2006-03-10 → 2006-03-02 (-8d) |  | 77d → 50d |
| 125 | Staging application connectivity | 2006-03-10 → 2006-03-02 (-8d) | 2006-03-10 → 2006-03-02 (-8d) |  | 77d → 50d |
| 126 | Staging connectivity, application encryption | 2006-03-10 → 2006-03-02 (-8d) | 2006-03-10 → 2006-03-02 (-8d) |  | 77d → 50d |
| 127 | Staging connectivity, network encryption | 2006-03-10 → 2006-03-02 (-8d) | 2006-03-14 → 2006-03-03 (-11d) | 3d → 2d | 46d → 23d |
| 128 | Staging connectivity testing complete | 2006-03-14 → 2006-03-03 (-11d) | 2006-03-14 → 2006-03-03 (-11d) |  | 46d → 23d |
| 129 | Production firewall connectivity | 2006-03-10 → 2006-03-02 (-8d) | 2006-03-10 → 2006-03-02 (-8d) |  | 77d → 50d |
| 130 | Production application connectivity | 2006-03-10 → 2006-03-02 (-8d) | 2006-03-10 → 2006-03-02 (-8d) |  | 77d → 50d |
| 131 | Production connectivity, application encryption | 2006-03-10 → 2006-03-02 (-8d) | 2006-03-10 → 2006-03-02 (-8d) |  | 77d → 50d |
| 132 | Production connectivity, network encryption | 2006-03-10 → 2006-03-02 (-8d) | 2006-03-14 → 2006-03-03 (-11d) | 3d → 2d | 73d → 47d |
| 133 | Production connectivity testing complete | 2006-03-14 → 2006-03-03 (-11d) | 2006-03-14 → 2006-03-03 (-11d) |  | 73d → 47d |
| 134 | **Partner SCRIPT Interface Test** | 2006-05-18 → 2006-04-06 (-42d) | 2006-05-26 → 2006-04-12 (-44d) | 7d → 5d |  |
| 135 | Partner system testing | 2006-05-18 → 2006-04-06 (-42d) | 2006-05-26 → 2006-04-12 (-44d) | 7d → 5d |  |
| 136 | SCRIPT interface testing complete | 2006-05-26 → 2006-04-12 (-44d) | 2006-05-26 → 2006-04-12 (-44d) |  |  |
| 137 | **Directory Interface Test** | 2006-03-24 → 2006-03-14 (-10d) | 2006-04-04 → 2006-03-21 (-14d) | 8d → 6d | 38d → 16d |
| 138 | Download file to partner system | 2006-03-24 → 2006-03-14 (-10d) | 2006-03-24 → 2006-03-14 (-10d) |  | 38d → 16d |
| 139 | Import download data to partner system | 2006-03-27 → 2006-03-15 (-12d) | 2006-03-28 → 2006-03-16 (-12d) |  | 38d → 16d |
| 140 | Download data reconciled successfully | 2006-03-29 → 2006-03-17 (-12d) | 2006-03-30 → 2006-03-17 (-13d) | 2d → 1d | 38d → 16d |
| 141 | Web service add/update entries successfully | 2006-03-31 → 2006-03-20 (-11d) | 2006-03-31 → 2006-03-20 (-11d) |  | 38d → 16d |
| 142 | Admin module add/update user successfully | 2006-04-03 → 2006-03-21 (-13d) | 2006-04-04 → 2006-03-21 (-14d) | 2d → 1d | 38d → 16d |
| 143 | Directory interface testing complete | 2006-04-04 → 2006-03-21 (-14d) | 2006-04-04 → 2006-03-21 (-14d) |  | 38d → 16d |
| 144 | Pre-Certification testing complete | 2006-05-26 → 2006-04-12 (-44d) | 2006-05-26 → 2006-04-12 (-44d) |  |  |
| 145 | OLA Executed | 2006-05-26 → 2006-04-12 (-44d) | 2006-05-26 → 2006-04-12 (-44d) |  |  |
| 146 | **Certification** | 2006-05-29 → 2006-04-13 (-46d) | 2006-06-15 → 2006-05-02 (-44d) |  |  |
| 147 | Detailed message review, element use | 2006-05-29 → 2006-04-13 (-46d) | 2006-05-30 → 2006-04-14 (-46d) |  | 20d → 19d |
| 148 | Detailed workflow review, screenshots | 2006-05-29 → 2006-04-13 (-46d) | 2006-05-30 → 2006-04-14 (-46d) |  |  |

| ID | Task | Start | Finish | Duration | Total float |
| --- | --- | --- | --- | --- | --- |
| 149 | Config test platform for partner certification | 2006-05-29 → 2006-04-13 (-46d) | 2006-05-29 → 2006-04-13 (-46d) |  | 21d → 20d |
| 150 | NEWRX tests | 2006-05-31 → 2006-04-17 (-44d) | 2006-06-01 → 2006-04-18 (-44d) |  |  |
| 151 | REFREQ tests | 2006-06-02 → 2006-04-19 (-44d) | 2006-06-05 → 2006-04-20 (-46d) |  |  |
| 152 | REFRES tests | 2006-06-06 → 2006-04-21 (-46d) | 2006-06-07 → 2006-04-24 (-44d) |  |  |
| 153 | Scheduled drug test | 2006-06-08 → 2006-04-25 (-44d) | 2006-06-08 → 2006-04-25 (-44d) |  |  |
| 154 | Free standing ERROR test | 2006-06-09 → 2006-04-26 (-44d) | 2006-06-09 → 2006-04-26 (-44d) |  |  |
| 155 | Failover test, to fax | 2006-06-12 → 2006-04-27 (-46d) | 2006-06-12 → 2006-04-27 (-46d) |  |  |
| 156 | Directory web services tests | 2006-06-13 → 2006-04-28 (-46d) | 2006-06-13 → 2006-04-28 (-46d) |  |  |
| 157 | Final review of all messages and screenshots | 2006-06-14 → 2006-05-01 (-44d) | 2006-06-15 → 2006-05-02 (-44d) |  |  |
| 158 | Partner questionnaire to SureScripts | 2006-06-08 → 2006-04-25 (-44d) | 2006-06-08 → 2006-04-25 (-44d) |  | 13d → 12d |
| 159 | Certification complete | 2006-06-15 → 2006-05-02 (-44d) | 2006-06-15 → 2006-05-02 (-44d) |  |  |
| 160 | **Production Readiness Phase** | 2006-06-16 → 2006-05-03 (-44d) | 2006-06-27 → 2006-05-11 (-47d) | 8d → 7d |  |
| 161 | **Setup** | 2006-06-16 → 2006-05-03 (-44d) | 2006-06-26 → 2006-05-10 (-47d) | 7d → 6d |  |
| 162 | Partner SCRIPT interface production deployment | 2006-06-16 → 2006-05-03 (-44d) | 2006-06-20 → 2006-05-04 (-47d) | 3d → 2d |  |
| 163 | Partner directory interface production deployment | 2006-06-21 → 2006-05-05 (-47d) | 2006-06-21 → 2006-05-05 (-47d) |  |  |
| 164 | SureScripts messaging, server setup | 2006-06-22 → 2006-05-08 (-45d) | 2006-06-22 → 2006-05-08 (-45d) |  |  |
| 165 | Identify/add support users for Admin Console access | 2006-06-23 → 2006-05-09 (-45d) | 2006-06-23 → 2006-05-09 (-45d) |  |  |
| 166 | Initial partner directory data loaded | 2006-06-23 → 2006-05-09 (-45d) | 2006-06-23 → 2006-05-09 (-45d) |  |  |
| 167 | Reconfirm network connectivity | 2006-06-26 → 2006-05-10 (-47d) | 2006-06-26 → 2006-05-10 (-47d) |  |  |
| 168 | Production setup complete | 2006-06-26 → 2006-05-10 (-47d) | 2006-06-26 → 2006-05-10 (-47d) |  |  |
| 169 | **Support** | 2006-06-16 → 2006-05-03 (-44d) | 2006-06-27 → 2006-05-11 (-47d) | 8d → 7d |  |
| 170 | Admin Console, User Training | 2006-06-26 → 2006-05-10 (-47d) | 2006-06-26 → 2006-05-10 (-47d) |  |  |
| 171 | Brief partner on SureScripts support services | 2006-06-27 → 2006-05-11 (-47d) | 2006-06-27 → 2006-05-11 (-47d) |  |  |
| 172 | All partner support email/contacts received | 2006-06-16 → 2006-05-03 (-44d) | 2006-06-19 → 2006-05-04 (-46d) |  | 5d → 4d |
| 173 | All partner support escalation contacts received | 2006-06-16 → 2006-05-03 (-44d) | 2006-06-19 → 2006-05-04 (-46d) |  | 5d → 4d |
| 174 | All partner support contacts added to SureScripts Support System | 2006-06-20 → 2006-05-05 (-46d) | 2006-06-20 → 2006-05-05 (-46d) |  | 5d → 4d |
| 175 | Implementation Closeout Meeting | 2006-06-27 → 2006-05-11 (-47d) | 2006-06-27 → 2006-05-11 (-47d) |  |  |
